# ITP-3 Project Schedule with Task Dependency Links

Schedule from MS Project, 2020-09-10 to 2021-03-18, costs in $.

## Calendars

- Standard: Mon-Fri 08:00-12:00, 13:00-17:00; Sat-Sun off.

## Resources

| Resource |
| --- |
| Quinston |
| Jarvis |
| Charles |
| Nick |
| Jahanzeb |
| Caleb |
| Sam |
| Jessica |
| Ashley |
| Brittany |
| Tanisha |
| Rudy |
| Peter |
| Miguel |

## Schedule

| ID | WBS | Task | Type | Duration | Start | Finish | Predecessors | Baseline finish | Total slack | Constraint | Resources | Work | Cost |
| --- | --- | --- | --- | --- | --- | --- | --- | --- | --- | --- | --- | --- | --- |
| 1 | 1 | **Mamma's Bakery and Sandwich Shoppe** |  | 136d | 2020-09-10 | 2021-03-18 |  | 2022-01-07 | 0d |  |  | 3772h | 1,170 |
| 2 | 1.1 | Begin Project | milestone | 0d | 2020-09-10 | 2020-09-10 |  | 2020-09-10 | 0d |  | Quinston |  | 10 |
| 3 | 1.2 | Initial meeting with customer |  | 1d | 2020-09-10 | 2020-09-10 | 2 | 2020-09-10 | 0d |  | Quinston | 8h | 10 |
| 4 | 1.3 | **Stakeholder Monthly Meetings** |  | 106d | 2020-10-12 | 2021-03-08 |  |  | 8d |  |  | 48h | 60 |
| 5 | 1.3.1 | Stakeholder Monthly Meetings 1 |  | 1d | 2020-10-12 | 2020-10-12 | 3 |  | 113d | start no earlier than 2020-10-12 | Quinston | 8h | 10 |
| 6 | 1.3.2 | Stakeholder Monthly Meetings 2 |  | 1d | 2020-11-09 | 2020-11-09 |  |  | 93d | start no earlier than 2020-11-09 | Quinston | 8h | 10 |
| 7 | 1.3.3 | Stakeholder Monthly Meetings 3 |  | 1d | 2020-12-14 | 2020-12-14 |  |  | 68d | start no earlier than 2020-12-14 | Quinston | 8h | 10 |
| 8 | 1.3.4 | Stakeholder Monthly Meetings 4 |  | 1d | 2021-01-11 | 2021-01-11 |  |  | 48d | start no earlier than 2021-01-11 | Quinston | 8h | 10 |
| 9 | 1.3.5 | Stakeholder Monthly Meetings 5 |  | 1d | 2021-02-08 | 2021-02-08 |  |  | 28d | start no earlier than 2021-02-08 | Quinston | 8h | 10 |
| 10 | 1.3.6 | Stakeholder Monthly Meetings 6 |  | 1d | 2021-03-08 | 2021-03-08 |  |  | 8d | start no earlier than 2021-03-08 | Quinston | 8h | 10 |
| 11 | 1.4 | **Weekly Internal Project Reviews** |  | 124d | 2020-09-22 | 2021-03-12 |  |  | 4d |  |  | 416h | 260 |
| 12 | 1.4.1 | Weekly Internal Project Reviews 1 |  | 1d | 2020-09-22 | 2020-09-22 | 3, 39, 40, 41 |  | 127d | start no earlier than 2020-09-18 | Ashley; Jessica | 16h | 10 |
| 13 | 1.4.2 | Weekly Internal Project Reviews 2 |  | 1d | 2020-09-25 | 2020-09-25 |  |  | 124d | start no earlier than 2020-09-25 | Ashley; Jessica | 16h | 10 |
| 14 | 1.4.3 | Weekly Internal Project Reviews 3 |  | 1d | 2020-10-02 | 2020-10-02 |  |  | 119d | start no earlier than 2020-10-02 | Ashley; Jessica | 16h | 10 |
| 15 | 1.4.4 | Weekly Internal Project Reviews 4 |  | 1d | 2020-10-09 | 2020-10-09 |  |  | 114d | start no earlier than 2020-10-09 | Ashley; Jessica | 16h | 10 |
| 16 | 1.4.5 | Weekly Internal Project Reviews 5 |  | 1d | 2020-10-16 | 2020-10-16 |  |  | 109d | start no earlier than 2020-10-16 | Ashley; Jessica | 16h | 10 |
| 17 | 1.4.6 | Weekly Internal Project Reviews 6 |  | 1d | 2020-10-23 | 2020-10-23 |  |  | 104d | start no earlier than 2020-10-23 | Ashley; Jessica | 16h | 10 |
| 18 | 1.4.7 | Weekly Internal Project Reviews 7 |  | 1d | 2020-10-30 | 2020-10-30 |  |  | 99d | start no earlier than 2020-10-30 | Ashley; Jessica | 16h | 10 |
| 19 | 1.4.8 | Weekly Internal Project Reviews 8 |  | 1d | 2020-11-06 | 2020-11-06 |  |  | 94d | start no earlier than 2020-11-06 | Ashley; Jessica | 16h | 10 |
| 20 | 1.4.9 | Weekly Internal Project Reviews 9 |  | 1d | 2020-11-13 | 2020-11-13 |  |  | 89d | start no earlier than 2020-11-13 | Ashley; Jessica | 16h | 10 |
| 21 | 1.4.10 | Weekly Internal Project Reviews 10 |  | 1d | 2020-11-20 | 2020-11-20 |  |  | 84d | start no earlier than 2020-11-20 | Ashley; Jessica | 16h | 10 |
| 22 | 1.4.11 | Weekly Internal Project Reviews 11 |  | 1d | 2020-11-27 | 2020-11-27 |  |  | 79d | start no earlier than 2020-11-27 | Ashley; Jessica | 16h | 10 |
| 23 | 1.4.12 | Weekly Internal Project Reviews 12 |  | 1d | 2020-12-04 | 2020-12-04 |  |  | 74d | start no earlier than 2020-12-04 | Ashley; Jessica | 16h | 10 |
| 24 | 1.4.13 | Weekly Internal Project Reviews 13 |  | 1d | 2020-12-11 | 2020-12-11 |  |  | 69d | start no earlier than 2020-12-11 | Ashley; Jessica | 16h | 10 |
| 25 | 1.4.14 | Weekly Internal Project Reviews 14 |  | 1d | 2020-12-18 | 2020-12-18 |  |  | 64d | start no earlier than 2020-12-18 | Ashley; Jessica | 16h | 10 |
| 26 | 1.4.15 | Weekly Internal Project Reviews 15 |  | 1d | 2020-12-25 | 2020-12-25 |  |  | 59d | start no earlier than 2020-12-25 | Ashley; Jessica | 16h | 10 |
| 27 | 1.4.16 | Weekly Internal Project Reviews 16 |  | 1d | 2021-01-01 | 2021-01-01 |  |  | 54d | start no earlier than 2021-01-01 | Ashley; Jessica | 16h | 10 |
| 28 | 1.4.17 | Weekly Internal Project Reviews 17 |  | 1d | 2021-01-08 | 2021-01-08 |  |  | 49d | start no earlier than 2021-01-08 | Ashley; Jessica | 16h | 10 |
| 29 | 1.4.18 | Weekly Internal Project Reviews 18 |  | 1d | 2021-01-15 | 2021-01-15 |  |  | 44d | start no earlier than 2021-01-15 | Ashley; Jessica | 16h | 10 |
| 30 | 1.4.19 | Weekly Internal Project Reviews 19 |  | 1d | 2021-01-22 | 2021-01-22 |  |  | 39d | start no earlier than 2021-01-22 | Ashley; Jessica | 16h | 10 |
| 31 | 1.4.20 | Weekly Internal Project Reviews 20 |  | 1d | 2021-01-29 | 2021-01-29 |  |  | 34d | start no earlier than 2021-01-29 | Ashley; Jessica | 16h | 10 |
| 32 | 1.4.21 | Weekly Internal Project Reviews 21 |  | 1d | 2021-02-05 | 2021-02-05 |  |  | 29d | start no earlier than 2021-02-05 | Ashley; Jessica | 16h | 10 |
| 33 | 1.4.22 | Weekly Internal Project Reviews 22 |  | 1d | 2021-02-12 | 2021-02-12 |  |  | 24d | start no earlier than 2021-02-12 | Ashley; Jessica | 16h | 10 |
| 34 | 1.4.23 | Weekly Internal Project Reviews 23 |  | 1d | 2021-02-19 | 2021-02-19 |  |  | 19d | start no earlier than 2021-02-19 | Ashley; Jessica | 16h | 10 |
| 35 | 1.4.24 | Weekly Internal Project Reviews 24 |  | 1d | 2021-02-26 | 2021-02-26 |  |  | 14d | start no earlier than 2021-02-26 | Ashley; Jessica | 16h | 10 |
| 36 | 1.4.25 | Weekly Internal Project Reviews 25 |  | 1d | 2021-03-05 | 2021-03-05 |  |  | 9d | start no earlier than 2021-03-05 | Ashley; Jessica | 16h | 10 |
| 37 | 1.4.26 | Weekly Internal Project Reviews 26 |  | 1d | 2021-03-12 | 2021-03-12 |  |  | 4d | start no earlier than 2021-03-12 | Ashley; Jessica | 16h | 10 |

| ID | WBS | Task | Duration | Start | Finish | Predecessors | Baseline finish | Total slack | Resources | Work | Cost |
| --- | --- | --- | --- | --- | --- | --- | --- | --- | --- | --- | --- |
| 38 | 1.5 | **Create Project Requirements** | 7d | 2020-09-11 | 2020-09-21 |  | 2020-09-21 | 0d |  | 56h | 30 |
| 39 | 1.5.1 | Draft requirements | 1w | 2020-09-11 | 2020-09-17 | 3 | 2020-09-17 | 0d | Caleb | 40h | 10 |
| 40 | 1.5.2 | Review final requirements with customer | 1d | 2020-09-18 | 2020-09-18 | 39 | 2020-09-18 | 0d | Caleb | 8h | 10 |
| 41 | 1.5.3 | Approve requirements | 1d | 2020-09-21 | 2020-09-21 | 40 | 2020-09-21 | 0d | Caleb | 8h | 10 |
| 42 | 1.6 | **Design IT System** | 73d | 2020-09-22 | 2020-12-31 |  | 2021-01-05 | 0d |  | 1048h | 260 |
| 43 | 1.6.1 | Set up Site Survey Date w/Client | 1d | 2020-09-22 | 2020-09-22 | 41 | 2020-09-22 | 0d | Jahanzeb | 8h | 10 |
| 44 | 1.6.2 | **Perform Survey at Location** | 10d | 2020-09-30 | 2020-10-13 |  | 2020-10-13 | 0d |  | 96h | 40 |
| 45 | 1.6.2.1 | Determine Room Dimensions | 2d | 2020-09-30 | 2020-10-01 | 43FS+5d | 2020-10-01 | 0d | Jahanzeb | 16h | 10 |
| 46 | 1.6.2.2 | Determine Equipment/Network Placement | 2d | 2020-09-30 | 2020-10-01 | 43FS+5d | 2020-10-01 | 0d | Jahanzeb | 16h | 10 |
| 47 | 1.6.2.3 | Generate Room Drawings | 1w | 2020-10-02 | 2020-10-08 | 46, 45 | 2020-10-08 | 0d | Jahanzeb | 40h | 10 |
| 48 | 1.6.2.4 | Generate Site Survey Document | 3d | 2020-10-09 | 2020-10-13 | 46, 45, 47 | 2020-10-13 | 112d | Jahanzeb | 24h | 10 |
| 49 | 1.6.3 | **Build List of Materials** | 5d | 2020-10-09 | 2020-10-15 |  | 2020-10-23 | 0d |  | 64h | 20 |
| 50 | 1.6.3.1 | Determine All Materials Required | 1w | 2020-10-09 | 2020-10-15 | 45, 46, 47 | 2020-10-20 | 0d | Jessica | 40h | 10 |
| 51 | 1.6.3.2 | Generate LOM Document | 3d | 2020-10-13 | 2020-10-15 | 50FS-3d | 2020-10-23 | 110d | Jessica | 24h | 10 |
| 52 | 1.6.4 | **Analyze Software Options** | 5d | 2020-09-22 | 2020-09-28 |  | 2020-10-20 | 13d |  | 80h | 20 |
| 53 | 1.6.4.1 | Analyze SaaS Options | 1w | 2020-09-22 | 2020-09-28 | 41 | 2020-10-20 | 13d | Jessica | 40h | 10 |
| 54 | 1.6.4.2 | Analyze Point of Sale Systems | 1w | 2020-09-22 | 2020-09-28 | 41 | 2020-10-20 | 13d | Jessica | 40h | 10 |
| 55 | 1.6.5 | **Determine Costs** | 20d | 2020-10-16 | 2020-11-12 |  | 2020-11-17 | 0d |  | 280h | 90 |
| 56 | 1.6.5.1 | **Determine Hardware Costs** | 5d | 2020-10-16 | 2020-10-22 |  | 2020-10-27 | 0d |  | 80h | 20 |
| 57 | 1.6.5.1.1 | Retrieve Network Quotes | 1w | 2020-10-16 | 2020-10-22 | 50 | 2020-10-27 | 0d | Jarvis | 40h | 10 |
| 58 | 1.6.5.1.2 | Retrieve Equipment Quotes | 1w | 2020-10-16 | 2020-10-22 | 50 | 2020-10-27 | 0d | Jarvis | 40h | 10 |
| 59 | 1.6.5.2 | **Determine Software Costs** | 5d | 2020-10-16 | 2020-10-22 |  | 2020-10-27 | 0d |  | 120h | 30 |
| 60 | 1.6.5.2.1 | Retrieve SaaS Quotes | 1w | 2020-10-16 | 2020-10-22 | 50, 53 | 2020-10-27 | 0d | Jarvis | 40h | 10 |
| 61 | 1.6.5.2.2 | Retrieve POS System Quotes | 1w | 2020-10-16 | 2020-10-22 | 50, 54 | 2020-10-27 | 0d | Jarvis | 40h | 10 |
| 62 | 1.6.5.2.3 | Retrieve Website Estimates | 1w | 2020-10-16 | 2020-10-22 | 50 | 2020-10-27 | 0d | Jarvis | 40h | 10 |
| 63 | 1.6.5.3 | Set up Costs Meeting with Client | 1d | 2020-10-23 | 2020-10-23 | 57, 58, 60, 61, 62 | 2020-10-28 | 0d | Jarvis | 8h | 10 |
| 64 | 1.6.5.4 | Present Cost Estimates to Client | 1d | 2020-11-02 | 2020-11-02 | 63FS+5d | 2020-11-05 | 0d | Jarvis | 8h | 10 |
| 65 | 1.6.5.5 | Revise Cost Estimates | 1w | 2020-11-03 | 2020-11-09 | 64 | 2020-11-12 | 0d | Jarvis | 40h | 10 |
| 66 | 1.6.5.6 | Seek Cost Approval | 3d | 2020-11-10 | 2020-11-12 | 65 | 2020-11-17 | 0d | Jarvis | 24h | 10 |

| ID | WBS | Task | Duration | Start | Finish | Predecessors | Baseline finish | Total slack | Free slack | Constraint | Resources | Work | Cost |
| --- | --- | --- | --- | --- | --- | --- | --- | --- | --- | --- | --- | --- | --- |
| 67 | 1.6.6 | **Design Website Blueprint** | 34d | 2020-11-13 | 2020-12-30 |  | 2021-01-04 | 0d |  |  |  | 512h | 70 |
| 68 | 1.6.6.1 | Create site map | 2w | 2020-11-13 | 2020-11-26 | 66 | 2020-12-01 | 80d |  |  | Nick | 80h | 10 |
| 69 | 1.6.6.2 | Create wireframes | 2w | 2020-11-13 | 2020-11-26 | 66 | 2020-12-01 | 80d |  |  | Nick | 80h | 10 |
| 70 | 1.6.6.3 | Create Themes | 2w | 2020-11-13 | 2020-11-26 | 66 | 2020-12-01 | 80d |  |  | Nick | 80h | 10 |
| 71 | 1.6.6.4 | Develop Ordering System | 1mo | 2020-11-13 | 2020-12-10 | 66 | 2020-12-15 | 0d |  |  | Nick | 160h | 10 |
| 72 | 1.6.6.5 | **Website Content** | 13d | 2020-12-11 | 2020-12-29 |  | 2021-01-01 | 0d |  |  |  | 104h | 20 |
| 73 | 1.6.6.5.1 | Writing content | 8d | 2020-12-11 | 2020-12-22 | 71 | 2020-12-25 | 0d |  |  | Nick | 64h | 10 |
| 74 | 1.6.6.5.2 | Editing content | 5d | 2020-12-23 | 2020-12-29 | 73 | 2021-01-01 | 0d |  |  | Nick | 40h | 10 |
| 75 | 1.6.6.6 | Customer approval | 1d | 2020-12-30 | 2020-12-30 | 74 | 2021-01-04 | 0d |  |  | Nick | 8h | 10 |
| 76 | 1.6.7 | Review final design with customer | 1d | 2020-12-31 | 2020-12-31 | 75, 66 | 2021-01-05 | 0d |  |  | Nick | 8h | 10 |
| 77 | 1.7 | **Procure Hardware/Network Equipment** | 31.5d | 2020-11-13 | 2020-12-28 |  | 2021-03-03 | 3.5d |  |  |  | 260h | 40 |
| 78 | 1.7.1 | Purchase Equipment | 3d | 2020-11-13 | 2020-11-17 | 66, 57, 58 | 2021-02-02 | 3.5d | 0d |  | Sam | 24h | 10 |
| 79 | 1.7.2 | Deliver Equipment | 5.5w | 2020-11-18 | 2020-12-25 | 78 | 2021-03-02 | 3.5d | 0d |  | Sam | 220h | 10 |
| 80 | 1.7.3 | Receive Equipment | 1d | 2020-12-25 | 2020-12-28 | 79 | 2021-03-03 | 58.5d |  |  | Sam | 8h | 10 |
| 81 | 1.7.4 | Store Equipment Temporarily | 1d | 2020-12-25 | 2020-12-28 | 79 | 2021-03-03 | 3.5d |  |  | Sam | 8h | 10 |
| 82 | 1.8 | **Procure Software** | 1d | 2020-11-13 | 2020-11-13 |  | 2021-01-27 | 48d |  |  |  | 8h | 10 |
| 83 | 1.8.1 | Purchase Software Online Keys | 1d | 2020-11-13 | 2020-11-13 | 60, 61, 62, 66 | 2021-01-27 | 48d | 43d |  | Sam | 8h | 10 |
| 84 | 1.9 | **Install System** | 20d | 2021-01-01 | 2021-01-28 |  | 2021-04-07 | 0d |  |  |  | 552h | 280 |
| 85 | 1.9.1 | Inventory Equipment | 1d | 2021-01-01 | 2021-01-01 | 81, 76 | 2021-03-04 | 0d |  |  | Sam | 8h | 10 |
| 86 | 1.9.2 | **Weekly Install Safety Inspections** | 11d | 2021-01-07 | 2021-01-21 |  |  | 38d |  |  |  | 24h | 30 |
| 87 | 1.9.2.1 | Weekly Install Safety Inspections 1 | 1d | 2021-01-07 | 2021-01-07 | 85 |  | 46d | 4d | start no earlier than 2021-01-07 | Sam | 8h | 10 |
| 88 | 1.9.2.2 | Weekly Install Safety Inspections 2 | 1d | 2021-01-14 | 2021-01-14 | 87 |  | 42d | 4d | start no earlier than 2021-01-14 | Sam | 8h | 10 |
| 89 | 1.9.2.3 | Weekly Install Safety Inspections 3 | 1d | 2021-01-21 | 2021-01-21 | 88 |  | 38d | 0d | start no earlier than 2021-01-21 | Sam | 8h | 10 |
| 90 | 1.9.3 | **Install Network Equipment** | 16d | 2021-01-04 | 2021-01-25 |  | 2021-03-25 | 0d |  |  |  | 144h | 110 |
| 91 | 1.9.3.1 | Install Panduit | 3d | 2021-01-04 | 2021-01-06 | 85 | 2021-03-09 | 0d |  |  | Tanisha | 24h | 10 |
| 92 | 1.9.3.2 | Install Service Rack | 1d | 2021-01-04 | 2021-01-04 | 85 | 2021-03-05 | 5d | 0d |  | Tanisha | 8h | 10 |
| 93 | 1.9.3.3 | Install Grounding | 1d | 2021-01-05 | 2021-01-05 | 85, 92 | 2021-03-08 | 51d | 0d |  | Tanisha | 8h | 10 |
| 94 | 1.9.3.4 | Install Router | 1d | 2021-01-06 | 2021-01-06 | 85, 92, 93 | 2021-03-09 | 51d |  |  | Tanisha | 8h | 10 |

| ID | WBS | Task | Duration | Start | Finish | Predecessors | Baseline finish | Total slack | Free slack | Resources | Work | Cost |
| --- | --- | --- | --- | --- | --- | --- | --- | --- | --- | --- | --- | --- |
| 95 | 1.9.3.5 | **Install CAT 6 Cabling** | 4d | 2021-01-07 | 2021-01-12 |  | 2021-03-17 | 0d |  |  | 56h | 30 |
| 96 | 1.9.3.5.1 | Run Cable | 3d | 2021-01-07 | 2021-01-11 | 91, 92SF | 2021-03-12 | 0d |  | Tanisha | 24h | 10 |
| 97 | 1.9.3.5.2 | Install Cable Management | 3d | 2021-01-07 | 2021-01-11 | 96SS | 2021-03-16 | 0d |  | Tanisha | 24h | 10 |
| 98 | 1.9.3.5.3 | Terminate | 1d | 2021-01-12 | 2021-01-12 | 96, 97 | 2021-03-17 | 0d |  | Tanisha | 8h | 10 |
| 99 | 1.9.3.6 | Install FO Cable to ISP Location | 1d | 2021-01-05 | 2021-01-05 | 92 | 2021-03-08 | 5d | 0d | Tanisha | 8h | 10 |
| 100 | 1.9.3.7 | **Test Network System** | 14d | 2021-01-06 | 2021-01-25 |  | 2021-03-25 | 38d |  |  | 32h | 30 |
| 101 | 1.9.3.7.1 | Test ISP Cables | 1d | 2021-01-12 | 2021-01-12 | 98SS | 2021-03-18 | 46d | 8d | Tanisha | 8h | 10 |
| 102 | 1.9.3.7.2 | Test Router to Internet | 1d | 2021-01-06 | 2021-01-06 | 99 | 2021-03-09 | 50d | 12d | Tanisha | 8h | 10 |
| 103 | 1.9.3.7.3 | Generate Test Acceptance Form | 2d | 2021-01-22 | 2021-01-25 | 101SS, 102SS, 87, 88, 89 | 2021-03-25 | 38d |  | Tanisha | 16h | 10 |
| 104 | 1.9.4 | **Install Hardware Equipment** | 13d | 2021-01-04 | 2021-01-20 |  | 2021-03-30 | 0d |  |  | 272h | 80 |
| 105 | 1.9.4.1 | Install Menu Monitors | 5d | 2021-01-04 | 2021-01-08 | 85 | 2021-03-08 | 2d |  | Jahanzeb | 40h | 10 |
| 106 | 1.9.4.2 | Install PCs | 5d | 2021-01-04 | 2021-01-08 | 85 | 2021-03-08 | 2d |  | Jahanzeb | 40h | 10 |
| 107 | 1.9.4.3 | Install VOIP Phones | 5d | 2021-01-04 | 2021-01-08 | 85 | 2021-03-08 | 2d |  | Jahanzeb | 40h | 10 |
| 108 | 1.9.4.4 | Install iPad Registers | 5d | 2021-01-04 | 2021-01-08 | 85 | 2021-03-08 | 2d |  | Jahanzeb | 40h | 10 |
| 109 | 1.9.4.5 | Install Payment Readers | 5d | 2021-01-04 | 2021-01-08 | 85 | 2021-03-08 | 2d |  | Jahanzeb | 40h | 10 |
| 110 | 1.9.4.6 | Connect to System Network | 1d | 2021-01-13 | 2021-01-13 | 98, 99, 105, 106, 107, 108, 109 | 2021-03-18 | 0d |  | Jahanzeb | 8h | 10 |
| 111 | 1.9.4.7 | Test Hardware Equipment | 3d | 2021-01-14 | 2021-01-18 | 110 | 2021-03-25 | 0d |  | Jahanzeb | 24h | 10 |
| 112 | 1.9.4.8 | Generate Test Acceptance Form | 5d | 2021-01-14 | 2021-01-20 | 111SS | 2021-03-30 | 0d |  | Jahanzeb | 40h | 10 |
| 113 | 1.9.5 | **Install a Point of Sale System** | 7d | 2021-01-14 | 2021-01-22 |  | 2021-04-01 | 4d |  |  | 24h | 20 |
| 114 | 1.9.5.1 | Install Point of Sale hardware | 1d | 2021-01-14 | 2021-01-14 | 106, 108, 109, 110, 83 | 2021-03-19 | 8d | 4d | Caleb | 8h | 10 |
| 115 | 1.9.5.2 | Install Point of Sale software | 2d | 2021-01-21 | 2021-01-22 | 114, 112, 83 | 2021-04-01 | 4d |  | Caleb | 16h | 10 |
| 116 | 1.9.6 | **Setup Quickbooks SaaS** | 6d | 2021-01-21 | 2021-01-28 |  | 2021-04-07 | 0d |  |  | 80h | 30 |
| 117 | 1.9.6.1 | Install Finance/Bookkeeping Software | 2d | 2021-01-21 | 2021-01-22 | 112, 83 | 2021-04-01 | 4d |  | Rudy | 16h | 10 |
| 118 | 1.9.6.2 | Install Inventory Management Software | 2d | 2021-01-21 | 2021-01-22 | 112, 83 | 2021-04-01 | 4d |  | Rudy | 16h | 10 |
| 119 | 1.9.6.3 | Install Payroll Management Software | 6d | 2021-01-21 | 2021-01-28 | 112, 83 | 2021-04-07 | 0d |  | Rudy | 48h | 10 |

| ID | WBS | Task | Type | Duration | Start | Finish | Predecessors | Baseline finish | Total slack | Free slack | Resources | Work | Cost |
| --- | --- | --- | --- | --- | --- | --- | --- | --- | --- | --- | --- | --- | --- |
| 120 | 1.10 | **Create Website** |  | 33d | 2021-01-01 | 2021-02-16 |  | 2021-02-19 | 22d |  |  | 264h | 50 |
| 121 | 1.10.1 | **Begin Coding** |  | 28d | 2021-01-01 | 2021-02-09 |  | 2021-02-12 | 22d |  |  | 224h | 40 |
| 122 | 1.10.1.1 | Development |  | 4w | 2021-01-01 | 2021-01-28 | 76 | 2021-02-02 | 22d | 0d | Peter | 160h | 10 |
| 123 | 1.10.1.2 | Code review |  | 5d | 2021-01-29 | 2021-02-04 | 122 | 2021-02-09 | 22d | 0d | Peter | 40h | 10 |
| 124 | 1.10.1.3 | Code testing |  | 2d | 2021-02-05 | 2021-02-08 | 123 | 2021-02-11 | 22d | 0d | Peter | 16h | 10 |
| 125 | 1.10.1.4 | Review and approve test results |  | 1d | 2021-02-09 | 2021-02-09 | 124 | 2021-02-12 | 22d | 0d | Peter | 8h | 10 |
| 126 | 1.10.2 | Deployment |  | 1w | 2021-02-10 | 2021-02-16 | 125 | 2021-02-19 | 22d |  | Peter | 40h | 10 |
| 127 | 1.11 | **Test Software** |  | 26d | 2021-01-01 | 2021-02-05 |  | 2021-04-15 | 29d |  |  | 128h | 40 |
| 128 | 1.11.1 | Create test plan |  | 1w | 2021-01-01 | 2021-01-07 | 76 | 2021-01-12 | 45d | 0d | Rudy | 40h | 10 |
| 129 | 1.11.2 | Create test cases |  | 1w | 2021-01-08 | 2021-01-14 | 128 | 2021-01-19 | 45d |  | Rudy | 40h | 10 |
| 130 | 1.11.3 | Execute test |  | 1w | 2021-01-29 | 2021-02-04 | 115, 117, 118, 119 | 2021-04-14 | 29d | 0d | Rudy | 40h | 10 |
| 131 | 1.11.4 | Approve test results |  | 1d | 2021-02-05 | 2021-02-05 | 130 | 2021-04-15 | 29d |  | Rudy | 8h | 10 |
| 132 | 1.12 | **Train Employees** |  | 27d | 2021-01-29 | 2021-03-08 |  | 2021-12-28 | 0d |  |  | 296h | 60 |
| 133 | 1.12.1 | **Create Training Blueprint** |  | 15d | 2021-01-29 | 2021-02-18 |  | 2021-04-28 | 0d |  |  | 200h | 30 |
| 134 | 1.12.1.1 | **Determine Needed Criteria** |  | 15d | 2021-01-29 | 2021-02-18 |  | 2021-04-28 | 0d |  |  | 200h | 30 |
| 135 | 1.12.1.1.1 | Develop Key Tasks |  | 2w | 2021-01-29 | 2021-02-11 | 115, 117, 118, 119 | 2021-04-21 | 0d |  | Miguel | 80h | 10 |
| 136 | 1.12.1.1.2 | Determine How-To Scenarios |  | 2w | 2021-01-29 | 2021-02-11 | 115, 117, 118, 119 | 2021-04-21 | 0d |  | Miguel | 80h | 10 |
| 137 | 1.12.1.1.3 | Input into Powerpoint |  | 1w | 2021-02-12 | 2021-02-18 | 135, 136 | 2021-04-28 | 0d |  | Miguel | 40h | 10 |
| 138 | 1.12.2 | Determine Training Schedule |  | 2d | 2021-02-19 | 2021-02-22 | 137 | 2021-04-30 | 0d |  | Miguel | 16h | 10 |
| 139 | 1.12.3 | Provide Training |  | 5d | 2021-03-02 | 2021-03-08 | 138FS+5d | 2021-12-28 | 0d |  | Miguel | 40h | 10 |
| 140 | 1.12.4 | Develop SOP for Future Use |  | 1w | 2021-02-19 | 2021-02-25 | 137 | 2021-05-05 | 10d | 0d | Miguel | 40h | 10 |
| 141 | 1.13 | **Complete Project** |  | 15d | 2021-02-26 | 2021-03-18 |  | 2022-01-07 | 0d |  |  | 688h | 60 |
| 142 | 1.13.1 | Project kick-off |  | 1d | 2021-03-09 | 2021-03-09 | 139 | 2021-12-29 | 4d | 0d | Charles; Quinston | 16h | 10 |
| 143 | 1.13.2 | **Seek Client Concurrance** |  | 8d | 2021-03-09 | 2021-03-18 |  | 2022-01-07 | 0d |  |  | 64h | 20 |
| 144 | 1.13.2.1 | Create Project Acceptance Form |  | 3d | 2021-03-09 | 2021-03-11 | 139 | 2021-12-31 | 0d |  | Charles | 24h | 10 |
| 145 | 1.13.2.2 | Retrieve Signatures |  | 1w | 2021-03-12 | 2021-03-18 | 144 | 2022-01-07 | 0d |  | Quinston | 40h | 10 |
| 146 | 1.13.3 | Deliver artifacts |  | 3d | 2021-03-10 | 2021-03-12 | 142 | 2022-01-03 | 4d |  | Miguel | 24h | 10 |
| 147 | 1.13.4 | Sign-Off Warranty Service Agreement |  | 3d | 2021-03-12 | 2021-03-16 | 144 | 2022-01-05 | 2d |  | Sam | 24h | 10 |
| 148 | 1.13.5 | Generate Lessons Learned Documents |  | 1w | 2021-02-26 | 2021-03-04 | 140 | 2021-05-12 | 10d |  | Ashley; Brittany; Caleb; Charles; Jahanzeb; Jarvis; Jessica; Miguel; Nick; Peter; Quinston; Rudy; Sam; Tanisha | 560h | 10 |
| 149 | 1.14 | End Project | milestone | 0d | 2021-03-18 | 2021-03-18 | 148, 145, 146, 147 | 2022-01-07 | 0d |  |  |  |  |
