# Simple Project Plan

Schedule from MS Project, 2012-01-03 to 2012-07-31, status date 2012-03-31, costs in $, A marks actual dates.

## Calendars

- Standard: Mon-Fri 08:00-12:00, 13:00-17:00; Sat-Sun off.

## Resources

| Resource | Rate |
| --- | --- |
| Marketing Staff | 80 |
| R&D | 80 |
| Engineering | 100 |
| Purchasing | 60 |
| Quality Engineering | 80 |
| Designers | 60 |
| Legal Staff | 120 |
| Production | 60 |

## Schedule

| ID | WBS | Task | Type | Duration | Start | Finish | Predecessors | Complete | Remaining | Actual finish | Baseline start | Baseline finish | Baseline duration | Total slack | Free slack | Resources | Work | Actual work | Cost | Baseline cost | Actual cost | LS | LF | EF | ES |
| --- | --- | --- | --- | --- | --- | --- | --- | --- | --- | --- | --- | --- | --- | --- | --- | --- | --- | --- | --- | --- | --- | --- | --- | --- | --- |
| 1 | 1 | 1.0 POM+ Project | manual | 1d? | 2012-01-03 | 2012-01-03 |  |  |  |  | 2012-01-03 | 2012-01-03 | 1d? |  |  |  |  |  |  |  |  | 150 | 151 |  |  |
| 2 | 2 | **1.1 R&D product development** |  | 42.5d | 2012-01-03 A | 2012-03-01 |  | 100% |  | 2012-03-19 | 2012-01-03 | 2012-03-01 | 42.5d |  |  |  | 2120h | 2120h | 169,600 | 112,000 | 169,600 |  |  |  |  |
| 3 | 2.1 | 1.1.1 Need survey |  | 23d | 2012-01-03 A | 2012-02-02 A |  | 100% |  |  | 2012-01-03 | 2012-01-30 | 20d |  |  | Marketing Staff [500%] | 920h | 920h | 73,600 | 64,000 | 73,600 |  | 23 | 23 |  |
| 4 | 2.2 | 1.1.2 Set product specs |  | 18d | 2012-02-03 A | 2012-02-28 A | 3 | 100% |  |  | 2012-01-31 | 2012-02-09 | 7.5d |  |  | Marketing Staff [400%]; R&D [200%] | 864h | 864h | 69,120 | 19,200 | 69,120 | 23 | 41 | 41 | 23 |
| 5 | 2.3 | 1.1.3 Shelf life report |  | 10d | 2012-02-29 A | 2012-03-13 A | 4 | 100% |  |  | 2012-02-09 | 2012-02-23 | 10d |  |  | R&D [300%] | 240h | 240h | 19,200 | 19,200 | 19,200 | 41 | 51 | 51 | 41 |
| 6 | 2.4 | 1.1.4 Nutrition report | manual | 4d | 2012-03-14 A | 2012-03-19 A | 4 | 100% |  |  | 2012-02-27 | 2012-03-02 | 5d |  |  | R&D [300%] | 96h | 96h | 7,680 | 9,600 | 7,680 | 51 | 55 | 55 | 51 |
| 7 | 3 | 1.2 Secure fruit suppliers | manual | 20d | 2012-03-07 | 2012-04-03 | 5, 6 |  |  |  | 2012-03-07 | 2012-04-03 | 20d |  |  | Purchasing | 160h |  | 9,600 | 9,600 |  | 61 | 81 | 66 | 46 |
| 8 | 4 | **1.3 Initial Production** |  | 80d | 2012-02-29 A | 2012-06-19 |  | 26% | 59.56d |  | 2012-02-09 | 2012-06-19 | 93.5d | 0d |  |  | 15120h | 5520h | 1,086,400 | 998,400 | 404,800 |  |  |  |  |
| 9 | 4.1 | 1.3.1 Equipment rehab |  | 35d | 2012-02-29 A | 2012-04-17 | 4 | 66% | 12d |  | 2012-02-09 | 2012-03-22 | 30d | 5d | 0d | Engineering [1000%]; Production [2000%] | 8400h | 5520h | 616,000 | 528,000 | 404,800 | 41 | 81 | 76 | 41 |
| 10 | 4.2 | 1.3.2 Production trials |  | 15d | 2012-04-18 | 2012-05-08 | 9, 7 |  |  |  | 2012-04-04 | 2012-04-24 | 15d | 5d | 0d | Production [1500%]; Purchasing; Engineering [1000%] | 3120h |  | 235,200 | 235,200 |  | 81 | 96 | 91 | 76 |
| 11 | 4.3 | 1.3.3 Quality trials |  | 20d | 2012-05-09 | 2012-06-05 | 10 |  |  |  | 2012-04-25 | 2012-05-22 | 20d | 5d | 0d | Quality Engineering [300%]; Production [500%] | 1280h |  | 86,400 | 86,400 |  | 96 | 116 | 111 | 91 |
| 12 | 4.4 | 1.3.4 Quality metrics |  | 5d | 2012-06-06 | 2012-06-12 | 11 |  |  |  | 2012-05-23 | 2012-05-29 | 5d | 5d | 0d | Quality Engineering [300%]; Production | 160h |  | 12,000 | 12,000 |  | 116 | 121 | 116 | 111 |
| 13 | 4.5 | 1.3.5 Quality training | manual | 15d | 2012-05-30 | 2012-06-19 | 12 |  |  |  | 2012-05-30 | 2012-06-19 | 15d |  |  | Quality Engineering [300%]; Production [1500%] | 2160h |  | 136,800 | 136,800 |  | 121 | 136 | 121 | 106 |
| 14 | 5 | **1.4 Distribution** |  | 70d | 2012-03-07 | 2012-06-12 |  |  |  |  | 2012-03-07 | 2012-06-12 | 70d |  |  |  | 2680h |  | 207,200 | 207,200 |  |  |  |  |  |
| 15 | 5.1 | 1.4.1 Market testing | manual | 30d | 2012-04-11 | 2012-05-22 | 5, 6 |  |  |  | 2012-04-11 | 2012-05-22 | 30d |  |  | Marketing Staff [500%] | 1200h |  | 96,000 | 96,000 |  | 71 | 101 | 101 | 71 |
| 16 | 5.2 | 1.4.2 Package design | manual | 40d | 2012-04-18 | 2012-06-12 | 15 |  |  |  | 2012-04-18 | 2012-06-12 | 30d |  |  | Designers [300%]; Marketing Staff | 480h |  | 31,200 | 31,200 |  | 96 | 136 | 116 | 76 |
| 17 | 5.3 | 1.4.3 Select distributors | manual | 25d | 2012-03-07 | 2012-04-10 | 5, 6 |  |  |  | 2012-03-07 | 2012-04-10 | 25d |  |  | Marketing Staff [500%] | 1000h |  | 80,000 | 80,000 |  | 111 | 136 | 71 | 46 |
| 18 | 6 | **1.5 Legal** |  | 45d | 2012-04-18 | 2012-06-19 |  |  |  |  | 2012-04-18 | 2012-06-19 | 45d |  |  |  | 720h |  | 86,400 | 86,400 |  |  |  |  |  |
| 19 | 6.1 | 1.5.1 Complete FDA certification | manual | 15d | 2012-04-18 | 2012-05-22 | 7, 15 |  |  |  | 2012-04-18 | 2012-05-22 | 15d |  |  | Legal Staff [500%] | 600h |  | 72,000 | 72,000 |  | 86.8 | 111 | 100.6 | 76.4 |
| 20 | 6.2 | 1.5.2 Register trademark | manual | 5d | 2012-06-13 | 2012-06-19 | 7, 15 |  |  |  | 2012-06-13 | 2012-06-19 | 5d |  |  | Legal Staff [300%] | 120h |  | 14,400 | 14,400 |  | 116 | 121 | 121 | 116 |
| 21 | 7 | 1.6 Prepare product launch | manual | 15d | 2012-07-11 | 2012-07-31 | 13, 16, 17, 19FS+25d, 20FS+15d |  |  |  | 2012-07-11 | 2012-07-31 | 15d |  |  | Quality Engineering [300%]; Purchasing [200%]; Production [1500%]; Marketing Staff [500%]; Engineering [500%]; R&D | 3720h |  | 268,800 | 268,800 |  | 136 | 151 | 151 | 136 |

Notes:
- 2: This is a summary task. Use summary tasks to help organize your project into sections.
- 5: This is a milestone task. Set a task to 0d duration to mark an event in your project.
- 15: Tasks with the pushpin next to them are manually scheduled tasks. Use them when you don't want Project to move the task. Also, you can enter freeform text in the duration, start and finish fields or leave them blank if you don't have all the information yet.
