# Nightingale project

Schedule from MS Project, 2017-01-02 to 2017-11-15.

## Calendars

- Standard: Mon-Fri 08:00-12:00, 13:00-17:00; Sat-Sun off. Exceptions (off unless hours are given): 2017-05-29 (Nonworking), 2017-07-04 (Nonworking), 2017-09-04 (Nonworking).

## Schedule

| ID | WBS | Task | Duration | Start | Finish | Predecessors | Total slack | Free slack |
| --- | --- | --- | --- | --- | --- | --- | --- | --- |
| 1 | 1 | Architectural decisions | 10d | 2017-01-02 | 2017-01-13 |  | 0d |  |
| 2 | 2 | Internal specifications | 20d | 2017-01-16 | 2017-02-10 | 1 | 20d | 0d |
| 3 | 3 | **External specifications** | 15d | 2017-01-16 | 2017-02-03 | 1 | 0d |  |
| 4 | 3.1 | Feature specifications | 15d | 2017-01-16 | 2017-02-03 | 1 | 0d |  |
| 5 | 4 | Voice recognition | 15d | 2017-02-13 | 2017-03-03 | 2, 3 | 20d |  |
| 6 | 5 | Case | 4d | 2017-02-13 | 2017-02-16 | 2, 3 | 31d |  |
| 7 | 6 | Screen | 2d | 2017-02-13 | 2017-02-14 | 2, 3 | 33d |  |
| 8 | 7 | Speaker output jacks | 2d | 2017-02-13 | 2017-02-14 | 2, 3 | 33d |  |
| 9 | 8 | Tape mechanism | 2d | 2017-02-13 | 2017-02-14 | 2, 3 | 33d |  |
| 10 | 9 | Database | 40d | 2017-02-06 | 2017-03-31 | 4 | 0d |  |
| 11 | 10 | Microphone/soundcard | 5d | 2017-02-06 | 2017-02-10 | 4 | 35d |  |
| 12 | 11 | Pager | 4d | 2017-02-06 | 2017-02-09 | 4 | 36d |  |
| 13 | 12 | Barcode reader | 3d | 2017-02-06 | 2017-02-08 | 4 | 37d |  |
| 14 | 13 | Alarm clock | 4d | 2017-02-06 | 2017-02-09 | 4 | 36d |  |
| 15 | 14 | Computer I/O | 5d | 2017-02-06 | 2017-02-10 | 4 | 35d |  |
| 16 | 15 | Review design | 10d | 2017-04-03 | 2017-04-14 | 5, 6, 7, 8, 9, 10, 11, 12, 13, 14, 15 | 0d |  |
| 17 | 16 | Price components | 5d | 2017-04-03 | 2017-04-07 | 5, 6, 7, 8, 9, 10, 11, 12, 13, 14, 15 | 5d |  |
| 18 | 17 | Integration | 15d | 2017-04-17 | 2017-05-05 | 16, 17 | 0d |  |
| 19 | 18 | Document design | 35d | 2017-04-17 | 2017-06-05 | 16 | 30d |  |
| 20 | 19 | Procure prototype components | 20d | 2017-05-08 | 2017-06-05 | 18 | 0d |  |
| 21 | 20 | Assemble prototypes | 10d | 2017-06-06 | 2017-06-19 | 20 | 0d |  |
| 22 | 21 | Lab test prototypes | 20d | 2017-06-20 | 2017-07-18 | 21 | 0d |  |
| 23 | 22 | Field test prototypes | 20d | 2017-07-19 | 2017-08-15 | 19, 22 | 0d |  |
| 24 | 23 | Adjust design | 20d | 2017-08-16 | 2017-09-13 | 23 | 0d |  |
| 25 | 24 | Order stock parts | 15d | 2017-09-14 | 2017-10-04 | 24 | 0d |  |
| 26 | 25 | Order custom parts | 2d | 2017-09-14 | 2017-09-15 | 24 | 13d |  |
| 27 | 26 | Assemble first production unit | 10d | 2017-10-05 | 2017-10-18 | 25, 26 | 0d |  |
| 28 | 27 | Test unit | 10d | 2017-10-19 | 2017-11-01 | 27 | 0d |  |

| ID | WBS | Task | Duration | Start | Finish | Predecessors | Total slack |
| --- | --- | --- | --- | --- | --- | --- | --- |
| 29 | 28 | **Produce 30 units** | 10d | 2017-11-02 | 2017-11-15 | 28 | 0d |
| 30 | 28.1 | Train sale representatives | 10d | 2017-11-02 | 2017-11-15 |  | 0d |
