# yourlastname-POM 1

Schedule from MS Project, 2021-01-04 to 2021-07-09, costs in $.

## Calendars

- Standard: Mon-Fri 08:00-12:00, 13:00-17:00; Sat-Sun off.

## Resources

| Resource | Rate |
| --- | --- |
| MRKT | 80 |
| R&D | 80 |
| PURCH | 60 |
| ENG | 100 |
| PROD | 60 |
| QUAL | 80 |
| DESIGN | 60 |
| LEGAL | 120 |

## Schedule

| ID | WBS | Task | Duration | Start | Finish | Predecessors | Total slack | Free slack | Constraint | Resources | Work | Cost |
| --- | --- | --- | --- | --- | --- | --- | --- | --- | --- | --- | --- | --- |
| 1 | 1 | **POM+Project** | 135d | 2021-01-04 | 2021-07-09 |  | 0d |  |  |  | 19720h | 1,497,600 |
| 2 | 1.1 | **R&D product development** | 65d | 2021-01-04 | 2021-04-02 |  | 0d |  |  |  | 960h | 73,600 |
| 3 | 1.1.1 | Need survey | 20d | 2021-01-04 | 2021-01-29 |  | 0d |  | start no earlier than 2021-01-04 | MRKT | 160h | 12,800 |
| 4 | 1.1.2 | Set product specs | 15d | 2021-02-01 | 2021-02-19 | 3 | 0d |  |  | R&D [400%]; MRKT [200%] | 360h | 28,800 |
| 5 | 1.1.3 | Shelf life report | 10d | 2021-02-22 | 2021-03-05 | 4 | 0d |  |  | R&D [300%] | 240h | 19,200 |
| 6 | 1.1.4 | Nutrition report | 1.67d | 2021-03-04 | 2021-03-05 | 4 | 0d |  |  | R&D [300%] | 40h | 3,200 |
| 7 | 1.1.5 | Select fruit suppliers | 20d | 2021-03-08 | 2021-04-02 | 5, 6 | 0d |  |  | PURCH | 160h | 9,600 |
| 8 | 1.2 | **Initial Praduction** | 85d | 2021-02-22 | 2021-06-18 |  | 0d |  |  |  | 11640h | 861,600 |
| 9 | 1.2.1 | Equipmant rabab | 30d | 2021-02-22 | 2021-04-02 | 4 | 0d |  |  | ENG [1000%]; PROD [2000%] | 7200h | 528,000 |
| 10 | 1.2.2 | Production trials | 15d | 2021-04-05 | 2021-04-23 | 7, 9 | 0d |  |  | PROD [1500%]; PURCH; ENG [1000%] | 2520h | 199,200 |
| 11 | 1.2.3 | Quality trials | 20d | 2021-04-26 | 2021-05-21 | 10 | 0d |  |  | QUAL [300%]; PROD [500%] | 1280h | 86,400 |
| 12 | 1.2.4 | Quality metrics | 5d | 2021-05-24 | 2021-05-28 | 11 | 0d |  |  | QUAL [300%]; PROD | 160h | 12,000 |
| 13 | 1.2.5 | Quality training | 15d | 2021-05-31 | 2021-06-18 | 12 | 0d |  |  | QUAL [300%]; PROD | 480h | 36,000 |
| 14 | 1.3 | **Distribution** | 70d | 2021-03-08 | 2021-06-11 |  | 5d |  |  |  | 2680h | 207,200 |
| 15 | 1.3.1 | Market testing | 30d | 2021-03-08 | 2021-04-16 | 5, 6 | 5d | 0d |  | MRKT [500%] | 1200h | 96,000 |
| 16 | 1.3.2 | Package design | 30d | 2021-04-19 | 2021-06-11 | 15 | 5d |  |  | DESIGN [300%]; MRKT | 480h | 31,200 |
| 17 | 1.3.3 | Select distributors | 25d | 2021-04-19 | 2021-05-21 | 7, 15 | 20d |  |  | MRKT [500%] | 1000h | 80,000 |
| 18 | 1.4 | **Legal** | 20d | 2021-04-19 | 2021-05-14 |  | 5d |  |  |  | 720h | 86,400 |
| 19 | 1.4.1 | Complete FDA certification | 15d | 2021-04-19 | 2021-05-07 | 7, 15 | 5d |  |  | LEGAL [500%] | 600h | 72,000 |
| 20 | 1.4.2 | Register trademark | 5d | 2021-05-10 | 2021-05-14 | 7, 15 | 10d |  |  | LEGAL [300%] | 120h | 14,400 |
| 21 | 1.5 | Prepare product lauch | 15d | 2021-06-21 | 2021-07-09 | 13, 16, 17, 19FS+25d, 20FS+15d | 0d |  |  | QUAL [300%]; PURCH [200%]; PROD [1500%]; MRKT [500%]; ENG [500%]; R&D | 3720h | 268,800 |
