# Project Plan Part1

Schedule from MS Project, 2020-06-02 to 2020-12-07.

## Calendars

- Standard: Mon-Fri 08:00-12:00, 13:00-17:00; Sat-Sun off.

## Schedule

| ID | WBS | Task | Duration | Start | Finish | Predecessors | Total slack | Free slack |
| --- | --- | --- | --- | --- | --- | --- | --- | --- |
| 1 | 1 | **POM+Project** | 135d | 2020-06-02 | 2020-12-07 |  | 0d |  |
| 2 | 1.1 | **R&D product development** | 65d | 2020-06-02 | 2020-08-31 |  | 0d |  |
| 3 | 1.1.1 | Need survey | 20d | 2020-06-02 | 2020-06-29 |  | 0d |  |
| 4 | 1.1.2 | Set product specs | 15d | 2020-06-30 | 2020-07-20 | 3 | 0d |  |
| 5 | 1.1.3 | Shelf life report | 10d | 2020-07-21 | 2020-08-03 | 4 | 0d |  |
| 6 | 1.1.4 | Nutrition report | 5d | 2020-07-21 | 2020-07-27 | 4 | 5d |  |
| 7 | 1.1.5 | Secure fruit suppliers | 20d | 2020-08-04 | 2020-08-31 | 5, 6 | 0d |  |
| 8 | 1.2 | **Initial Production** | 85d | 2020-07-21 | 2020-11-16 |  | 0d |  |
| 9 | 1.2.1 | Equipment rabab | 30d | 2020-07-21 | 2020-08-31 | 4 | 0d |  |
| 10 | 1.2.2 | Production trials | 15d | 2020-09-01 | 2020-09-21 | 7, 9 | 0d |  |
| 11 | 1.2.3 | Quality trials | 20d | 2020-09-22 | 2020-10-19 | 10 | 0d |  |
| 12 | 1.2.4 | Quality metrics | 5d | 2020-10-20 | 2020-10-26 | 11 | 0d |  |
| 13 | 1.2.5 | Quality training | 15d | 2020-10-27 | 2020-11-16 | 12 | 0d |  |
| 14 | 1.3 | **Distribution** | 55d | 2020-08-04 | 2020-10-19 |  | 5d |  |
| 15 | 1.3.1 | Market testing | 30d | 2020-08-04 | 2020-09-14 | 5, 6 | 5d | 0d |
| 16 | 1.3.2 | Package design | 15d | 2020-09-15 | 2020-10-05 | 15 | 30d |  |
| 17 | 1.3.3 | Select distributors | 25d | 2020-09-15 | 2020-10-19 | 7, 15 | 20d |  |
| 18 | 1.4 | **Legal** | 15d | 2020-09-15 | 2020-10-05 |  | 5d |  |
| 19 | 1.4.1 | Complete FDA certification | 15d | 2020-09-15 | 2020-10-05 | 7, 15 | 5d |  |
| 20 | 1.4.2 | Register trademark | 5d | 2020-09-15 | 2020-09-21 | 7, 15 | 25d |  |
| 21 | 1.5 | Prepare product launch | 15d | 2020-11-17 | 2020-12-07 | 13, 16, 17, 19FS+25d, 20FS+15d | 0d |  |
