Schedule from MS Project, 2017-07-03 to 2021-02-12, A marks actual dates.

## Calendars

- Standard: Mon-Fri 08:00-12:00, 13:00-17:00; Sat-Sun off.

## Schedule

| ID | Task | Duration | Start | Finish | Predecessors | Remaining | Total slack | Free slack |
| --- | --- | --- | --- | --- | --- | --- | --- | --- |
| 1 | Baseball Stadium | 945d | 2017-07-03 A | 2021-02-12 |  | 944d | 0d |  |
| 2 | Clear Stadium site | 70d | 2017-07-03 | 2017-10-06 |  |  | 0d |  |
| 3 | Demolish Building | 30d | 2017-10-09 | 2017-11-17 | 2 |  | 0d |  |
| 4 | Setup Construction site | 70d | 2017-11-20 | 2018-02-23 | 3 |  | 0d |  |
| 5 | Drive Support Piling | 120d | 2018-02-26 | 2018-08-10 | 4 |  | 0d |  |
| 6 | Power lower concrete bowl | 120d | 2018-08-13 | 2019-01-25 | 5 |  | 0d |  |
| 7 | Power Main Concourse | 120d | 2019-01-28 | 2019-07-12 | 6 |  | 415d |  |
| 8 | Install Playing Field | 90d | 2019-01-28 | 2019-05-31 | 6 |  | 425d |  |
| 9 | Construct upper steel bowl | 120d | 2019-01-28 | 2019-07-12 | 6 |  | 0d |  |
| 10 | Install seats | 140d | 2019-07-15 | 2020-01-24 | 9 |  | 0d |  |
| 11 | Build luxury boxes | 90d | 2019-07-15 | 2019-11-15 | 9 |  | 305d |  |
| 12 | Install jumbotron | 30d | 2019-07-15 | 2019-08-23 | 9 |  | 385d |  |
| 13 | Stadium infrastructure | 120d | 2019-07-15 | 2019-12-27 | 9 |  | 275d |  |
| 14 | Construct steel canopy | 75d | 2020-01-27 | 2020-05-08 | 10 |  | 0d |  |
| 15 | Light installation | 30d | 2020-01-27 | 2020-03-06 | 10 |  | 225d |  |
| 16 | Build roof supports | 90d | 2018-02-26 | 2018-06-29 | 4 |  | 395d | 0d |
| 17 | Construct roof | 180d | 2018-07-02 | 2019-03-08 | 16 |  | 395d |  |
| 18 | Install roof tracks | 90d | 2020-05-11 | 2020-09-11 | 14 |  | 0d |  |
| 19 | Install roof | 90d | 2020-09-14 | 2021-01-15 | 17, 18 |  | 0d |  |
| 20 | Inspection | 20d | 2021-01-18 | 2021-02-12 | 8, 11, 13, 15, 19 |  | 0d |  |
