# Week_2_WBS_MMBSS_IFSM438_Antonio

Schedule from MS Project, 2019-07-01 to 2019-11-04, costs in $.

## Calendars

- Standard: Mon-Fri 08:00-12:00, 13:00-17:00; Sat-Sun off. Exceptions (off unless hours are given): 2019-07-04 (4th of July Holiday), 2019-09-02 (Labor Day Holiday), 2019-10-14 (Columbus Day Holiday).

## Resources

| Resource | Rate | Cost per use |
| --- | --- | --- |
| Bruce Asberry | 65 |  |
| Marco Antonio Rodriguez | 55 |  |
| Mark Fowler | 45 |  |
| Micheal Mays | 50 |  |
| Tibletse Nigussie | 55 |  |
| Project Sponsor |  |  |
| SysPro ERP |  |  |
| Clover POS |  |  |
| Verizon FIOS |  |  |
| Cat 6A Cable |  | 1600 |
| Xerox All-in-1 printer |  | 350 |
| Nous (Web Developer) | 50 |  |
| Dell Vostro 15” Small Business Laptops |  | 2000 |
| Sophos XG 135 Wireless Next Generation Firewall |  | 1531 |

## Schedule

| ID | WBS | Task | Type | Duration | Start | Finish | Predecessors | Total slack | Free slack | Resources | Work | Cost |
| --- | --- | --- | --- | --- | --- | --- | --- | --- | --- | --- | --- | --- |
| 1 | 1 | **MMBSS Customer Relations System** |  | 87.64d | 2019-07-01 08:00 | 2019-11-04 14:07 |  | 0d |  |  | 1650.08h | 96,335.28 |
| 2 | 1.1 | **Project Initiation Phase** |  | 2.5d | 2019-07-01 08:00 | 2019-07-03 12:00 |  | 2d |  |  | 50h | 2,900 |
| 3 | 1.1.1 | **Project Team** |  | 1.5d | 2019-07-01 08:00 | 2019-07-02 12:00 |  | 2.5d | 0d |  | 12h | 780 |
| 4 | 1.1.1.1 | Identify Project Team Members and Establish Project Team |  | 1d | 2019-07-01 08:00 | 2019-07-01 17:00 |  | 2.5d | 0d | Bruce Asberry | 8h | 520 |
| 5 | 1.1.1.2 | Finalize Project Team Members |  | 0.5d | 2019-07-02 08:00 | 2019-07-02 12:00 | 4 | 2.5d | 0.5d | Bruce Asberry | 4h | 260 |
| 6 | 1.1.2 | **Project Kickoff** |  | 2.5d | 2019-07-01 08:00 | 2019-07-03 12:00 | 3SS | 2d |  |  | 38h | 2,120 |
| 7 | 1.1.2.1 | Schedule Kickoff Meeting |  | 0.25d | 2019-07-01 08:00 | 2019-07-01 10:00 | 3SS | 2d | 0d | Bruce Asberry | 2h | 130 |
| 8 | 1.1.2.2 | Prepare Draft Project Agenda |  | 0.5d | 2019-07-01 10:00 | 2019-07-01 15:00 | 7 | 2d | 0d | Bruce Asberry | 4h | 260 |
| 9 | 1.1.2.3 | Prepare Draft Kickoff Presentation |  | 0.5d | 2019-07-01 15:00 | 2019-07-02 10:00 | 8 | 2d | 0d | Bruce Asberry | 4h | 260 |
| 10 | 1.1.2.4 | Review and Finalize Project Agenda and Kickoff Presentation |  | 0.5d | 2019-07-02 10:00 | 2019-07-02 15:00 | 9 | 2d | 0d | Bruce Asberry | 4h | 260 |
| 11 | 1.1.2.5 | Deliver Project Kickoff Materials to Project Sponsor |  | 0.25d | 2019-07-02 15:00 | 2019-07-02 17:00 | 9, 10 | 2d | 0d | Bruce Asberry; Project Sponsor | 4h | 130 |
| 12 | 1.1.2.6 | Conduct Project Kickoff Meeting |  | 0.5d | 2019-07-02 17:00 | 2019-07-03 12:00 | 11, 5 | 2d | 0d | Bruce Asberry; Marco Antonio Rodriguez; Mark Fowler; Micheal Mays; Tibletse Nigussie; Project Sponsor | 20h | 1,080 |
| 13 | 1.2 | **Project Management Phase** |  | 72.75d | 2019-07-03 13:00 | 2019-10-17 10:00 | 2SS | 0d |  |  | 274h | 14,760 |
| 14 | 1.2.1 | **Project Scope** |  | 3d | 2019-07-03 13:00 | 2019-07-09 12:00 | 6SS | 2d |  |  | 24h | 1,560 |
| 15 | 1.2.1.1 | Analyze and Draft Project Scope |  | 2.25d | 2019-07-03 13:00 | 2019-07-08 15:00 | 12 | 2d | 0d | Bruce Asberry | 18h | 1,170 |
| 16 | 1.2.1.2 | Review Project Scope with Project Sponsor |  | 0.25d | 2019-07-08 15:00 | 2019-07-08 17:00 | 15 | 2d | 0d | Bruce Asberry | 2h | 130 |
| 17 | 1.2.1.3 | Update Project Scope based on Feedback |  | 0.25d | 2019-07-09 08:00 | 2019-07-09 10:00 | 16 | 2d | 0d | Bruce Asberry | 2h | 130 |
| 18 | 1.2.1.4 | Review Finalized Project Scope with Project Sponsor |  | 0.25d | 2019-07-09 10:00 | 2019-07-09 12:00 | 17 | 2d | 0d | Bruce Asberry | 2h | 130 |
| 19 | 1.2.1.5 | Obtain Project Sponsor Approval for Project Scope | milestone | 0d | 2019-07-09 12:00 | 2019-07-09 12:00 | 16, 18 | 2d | 0d | Project Sponsor |  |  |
| 20 | 1.2.2 | **Project Plan** |  | 3d | 2019-07-09 13:00 | 2019-07-12 12:00 | 6, 14SS | 2d | 0d |  | 106h | 5,660 |
| 21 | 1.2.2.1 | Review and Update Project Plan |  | 2d | 2019-07-09 13:00 | 2019-07-11 12:00 | 19 | 2d | 0d | Bruce Asberry; Mark Fowler; Marco Antonio Rodriguez; Micheal Mays; Tibletse Nigussie | 80h | 4,320 |
| 22 | 1.2.2.2 | Deliver Updated Project Plan to Project Sponsor |  | 0.25d | 2019-07-11 13:00 | 2019-07-11 15:00 | 21 | 2d | 0d | Bruce Asberry | 2h | 130 |
| 23 | 1.2.2.3 | Obtain and Incorporate Feedback from Project Sponsor |  | 0.5d | 2019-07-11 15:00 | 2019-07-12 10:00 | 22 | 2d | 0d | Bruce Asberry; Mark Fowler; Marco Antonio Rodriguez; Micheal Mays; Tibletse Nigussie | 20h | 1,080 |
| 24 | 1.2.2.4 | Review Final Project Plan with Project Sponsor |  | 0.25d | 2019-07-12 10:00 | 2019-07-12 12:00 | 23 | 2d | 0d | Bruce Asberry; Project Sponsor | 4h | 130 |
| 25 | 1.2.2.5 | Obtain Project Sponsor Approval and Sign-Off | milestone | 0d | 2019-07-12 12:00 | 2019-07-12 12:00 | 24 | 2d | 0d | Project Sponsor |  |  |

| ID | WBS | Task | Type | Duration | Start | Finish | Predecessors | Total slack | Free slack | Constraint | Resources | Work | Cost |
| --- | --- | --- | --- | --- | --- | --- | --- | --- | --- | --- | --- | --- | --- |
| 26 | 1.2.3 | **Project Meetings** |  | 66.25d | 2019-07-15 08:00 | 2019-10-17 10:00 | 6SS, 12 | 0d |  |  |  | 144h | 7,540 |
| 27 | 1.2.3.1 | **Weekly Status Meetings** |  | 59.25d | 2019-07-15 08:00 | 2019-10-07 10:00 |  | 6.75d |  |  |  | 130h | 7,020 |
| 28 | 1.2.3.1.1 | Conduct Weekly Status Meeting |  | 0.25d | 2019-07-15 08:00 | 2019-07-15 10:00 | 2 | 62.75d | 4.75d | start no earlier than 2019-07-15 08:00 | Micheal Mays; Marco Antonio Rodriguez; Mark Fowler; Tibletse Nigussie; Bruce Asberry | 10h | 540 |
| 29 | 1.2.3.1.2 | Conduct Weekly Status Meeting |  | 0.25d | 2019-07-22 08:00 | 2019-07-22 10:00 | 28 | 58d | 4.75d | start no earlier than 2019-07-22 08:00 | Micheal Mays; Marco Antonio Rodriguez; Mark Fowler; Tibletse Nigussie; Bruce Asberry | 10h | 540 |
| 30 | 1.2.3.1.3 | Conduct Weekly Status Meeting |  | 0.25d | 2019-07-29 08:00 | 2019-07-29 10:00 | 29 | 53.25d | 4.75d | start no earlier than 2019-07-29 08:00 | Micheal Mays; Marco Antonio Rodriguez; Mark Fowler; Tibletse Nigussie; Bruce Asberry | 10h | 540 |
| 31 | 1.2.3.1.4 | Conduct Weekly Status Meeting |  | 0.25d | 2019-08-05 08:00 | 2019-08-05 10:00 | 30 | 48.5d | 4.75d | start no earlier than 2019-08-05 08:00 | Micheal Mays; Marco Antonio Rodriguez; Mark Fowler; Tibletse Nigussie; Bruce Asberry | 10h | 540 |
| 32 | 1.2.3.1.5 | Conduct Weekly Status Meeting |  | 0.25d | 2019-08-12 08:00 | 2019-08-12 10:00 | 31 | 43.75d | 4.75d | start no earlier than 2019-08-12 08:00 | Micheal Mays; Marco Antonio Rodriguez; Mark Fowler; Tibletse Nigussie; Bruce Asberry | 10h | 540 |
| 33 | 1.2.3.1.6 | Conduct Weekly Status Meeting |  | 0.25d | 2019-08-19 08:00 | 2019-08-19 10:00 | 32 | 39d | 4.75d | start no earlier than 2019-08-19 08:00 | Micheal Mays; Marco Antonio Rodriguez; Mark Fowler; Tibletse Nigussie; Bruce Asberry | 10h | 540 |
| 34 | 1.2.3.1.7 | Conduct Weekly Status Meeting |  | 0.25d | 2019-08-26 08:00 | 2019-08-26 10:00 | 33 | 34.25d | 4.75d | start no earlier than 2019-08-26 08:00 | Micheal Mays; Marco Antonio Rodriguez; Mark Fowler; Tibletse Nigussie; Bruce Asberry | 10h | 540 |
| 35 | 1.2.3.1.8 | Conduct Weekly Status Meeting |  | 0.25d | 2019-09-03 08:00 | 2019-09-03 10:00 | 34 | 29.5d | 3.75d | start no earlier than 2019-09-02 08:00 | Micheal Mays; Marco Antonio Rodriguez; Mark Fowler; Tibletse Nigussie; Bruce Asberry | 10h | 540 |
| 36 | 1.2.3.1.9 | Conduct Weekly Status Meeting |  | 0.25d | 2019-09-09 08:00 | 2019-09-09 10:00 | 35 | 25.75d | 4.75d | start no earlier than 2019-09-09 08:00 | Micheal Mays; Marco Antonio Rodriguez; Mark Fowler; Tibletse Nigussie; Bruce Asberry | 10h | 540 |
| 37 | 1.2.3.1.10 | Conduct Weekly Status Meeting |  | 0.25d | 2019-09-16 08:00 | 2019-09-16 10:00 | 36 | 21d | 4.75d | start no earlier than 2019-09-16 08:00 | Micheal Mays; Marco Antonio Rodriguez; Mark Fowler; Tibletse Nigussie; Bruce Asberry | 10h | 540 |
| 38 | 1.2.3.1.11 | Conduct Weekly Status Meeting |  | 0.25d | 2019-09-23 08:00 | 2019-09-23 10:00 | 37 | 16.25d | 4.75d | start no earlier than 2019-09-23 08:00 | Micheal Mays; Marco Antonio Rodriguez; Mark Fowler; Tibletse Nigussie; Bruce Asberry | 10h | 540 |
| 39 | 1.2.3.1.12 | Conduct Weekly Status Meeting |  | 0.25d | 2019-09-30 08:00 | 2019-09-30 10:00 | 38 | 11.5d | 4.75d | start no earlier than 2019-09-30 08:00 | Micheal Mays; Marco Antonio Rodriguez; Mark Fowler; Tibletse Nigussie; Bruce Asberry | 10h | 540 |
| 40 | 1.2.3.1.13 | Conduct Weekly Status Meeting |  | 0.25d | 2019-10-07 08:00 | 2019-10-07 10:00 | 39 | 6.75d |  | start no earlier than 2019-10-07 08:00 | Bruce Asberry; Marco Antonio Rodriguez; Mark Fowler; Micheal Mays; Tibletse Nigussie | 10h | 540 |
| 41 | 1.2.3.2 | **Monthly Status Meetings** |  | 63.25d | 2019-07-18 08:00 | 2019-10-17 10:00 |  | 0d |  |  |  | 14h | 520 |
| 42 | 1.2.3.2.1 | Conduct Monthly Status Meeting with Project Sponsor |  | 0.25d | 2019-07-18 08:00 | 2019-07-18 10:00 | 2 | 62.25d | 19.75d | start no earlier than 2019-07-18 08:00 | Bruce Asberry; Project Sponsor | 2h | 130 |
| 43 | 1.2.3.2.2 | Conduct Monthly Status Meeting with Project Sponsor |  | 0.25d | 2019-08-15 08:00 | 2019-08-15 10:00 | 42 | 42.5d | 23.75d | start no earlier than 2019-08-15 08:00 | Bruce Asberry; Project Sponsor | 4h | 130 |
| 44 | 1.2.3.2.3 | Conduct Monthly Status Meeting with Project Sponsor |  | 0.25d | 2019-09-19 08:00 | 2019-09-19 10:00 | 43 | 18.75d |  | start no earlier than 2019-09-19 08:00 | Bruce Asberry; Project Sponsor | 4h | 130 |
| 45 | 1.2.3.2.4 | Conduct Monthly Status Meeting with Project Sponsor |  | 0.25d | 2019-10-17 08:00 | 2019-10-17 10:00 | 44, 40 | 0d |  | start no earlier than 2019-10-17 08:00 | Bruce Asberry; Project Sponsor | 4h | 130 |
| 46 | 1.3 | **Project Requirements Phase** |  | 9.14d | 2019-07-12 13:00 | 2019-07-25 14:07 | 13SS, 20 | 0d |  |  |  | 178.08h | 17,895.4 |
| 47 | 1.3.1 | **Business Requirements** |  | 4d | 2019-07-12 13:00 | 2019-07-18 12:00 | 19SS, 25SS | 2d |  |  |  | 32h | 2,080 |
| 48 | 1.3.1.1 | Schedule Business Requirements Sessions with Project Sponsor |  | 0.25d | 2019-07-12 13:00 | 2019-07-12 15:00 | 25 | 2d | 0d |  | Bruce Asberry | 2h | 130 |
| 49 | 1.3.1.2 | Extract and Review Business Requirements from Project Charter |  | 1d | 2019-07-12 15:00 | 2019-07-15 15:00 | 19, 48 | 2d | 0d |  | Bruce Asberry | 8h | 520 |
| 50 | 1.3.1.3 | Conduct Initial Business Requirements Session with Stakeholders |  | 1d | 2019-07-15 15:00 | 2019-07-16 15:00 | 49 | 2d | 0d |  | Bruce Asberry | 8h | 520 |
| 51 | 1.3.1.4 | Update Business Requirements based on Feedback Received |  | 0.5d | 2019-07-16 15:00 | 2019-07-17 10:00 | 50 | 2d | 0d |  | Bruce Asberry | 4h | 260 |
| 52 | 1.3.1.5 | Review Business Requirements Updates with Project Sponsor |  | 0.5d | 2019-07-17 10:00 | 2019-07-17 15:00 | 49, 51 | 2d | 0d |  | Bruce Asberry | 4h | 260 |
| 53 | 1.3.1.6 | Conduct Follow-up Business Requirements Session with Stakeholders |  | 0.25d | 2019-07-17 15:00 | 2019-07-17 17:00 | 52 | 2d | 0d |  | Bruce Asberry | 2h | 130 |
| 54 | 1.3.1.7 | Review and Finalize Business Requirements with Project Sponsor |  | 0.5d | 2019-07-18 08:00 | 2019-07-18 12:00 | 53 | 2d | 0d |  | Bruce Asberry | 4h | 260 |
| 55 | 1.3.1.8 | Obtain Business Requirements Sign-Off from Project Sponsor | milestone | 0d | 2019-07-18 12:00 | 2019-07-18 12:00 | 52, 54 | 2d | 0d |  | Project Sponsor |  |  |

| ID | WBS | Task | Type | Duration | Start | Finish | Predecessors | Total slack | Free slack | Resources | Work | Cost |
| --- | --- | --- | --- | --- | --- | --- | --- | --- | --- | --- | --- | --- |
| 56 | 1.3.2 | **System Requirements** |  | 2.14d | 2019-07-18 13:00 | 2019-07-22 14:07 | 55 | 2d | 0d |  | 70.08h | 6,664.4 |
| 57 | 1.3.2.1 | **SysPro ERP** |  | 1.38d | 2019-07-18 13:00 | 2019-07-19 16:02 | 47SS | 2d | 0.76d |  | 22h | 2,750 |
| 58 | 1.3.2.1.1 | Identify SysPro ERP Requirements (hardware, software, licenses, etc.) |  | 0.5d | 2019-07-18 13:00 | 2019-07-18 17:00 | 25, 55 | 2d | 0d | Marco Antonio Rodriguez; Tibletse Nigussie | 8h | 440 |
| 59 | 1.3.2.1.2 | Review and Finalize SysPro ERP Requirements |  | 0.5d | 2019-07-19 08:00 | 2019-07-19 12:00 | 58 | 2d | 0d | Marco Antonio Rodriguez; Tibletse Nigussie; Bruce Asberry | 12h | 700 |
| 60 | 1.3.2.1.3 | Submit SysPro ERP Purchase Order for Approval | milestone | 0d | 2019-07-19 12:00 | 2019-07-19 14:02 | 59 | 2d | 0d | Bruce Asberry; SysPro ERP [0.1%] |  | 1,500 |
| 61 | 1.3.2.1.4 | Obtain Purchase Order Approval for SysPro ERP | milestone | 0d | 2019-07-19 14:02 | 2019-07-19 14:02 | 59, 60 | 2d | 0d | Bruce Asberry; Project Sponsor |  |  |
| 62 | 1.3.2.1.5 | Submit Purchase Order to SysPro |  | 0.25d | 2019-07-19 14:02 | 2019-07-19 16:02 | 61 | 2.76d | 0.76d | Tibletse Nigussie | 2h | 110 |
| 63 | 1.3.2.2 | **Clover POS** |  | 1.38d | 2019-07-18 13:00 | 2019-07-19 16:02 | 47SS | 2.76d | 0.76d |  | 26h | 2,710 |
| 64 | 1.3.2.2.1 | Identify Clover POS Requirements (hardware, software, licenses, etc.) |  | 0.5d | 2019-07-18 13:00 | 2019-07-18 17:00 | 55, 25 | 2.76d | 0d | Clover POS [0.1%]; Marco Antonio Rodriguez; Tibletse Nigussie; Bruce Asberry | 12h | 700 |
| 65 | 1.3.2.2.2 | Review and Finalize Clover POS Requirements |  | 0.5d | 2019-07-19 08:00 | 2019-07-19 12:00 | 64 | 2.76d | 0d | Marco Antonio Rodriguez; Tibletse Nigussie; Bruce Asberry | 12h | 700 |
| 66 | 1.3.2.2.3 | Submit Clover POS Purchase Order for Approval | milestone | 0d | 2019-07-19 12:00 | 2019-07-19 14:02 | 65 | 2.76d | 0d | Bruce Asberry; Clover POS [0.1%] |  | 1,200 |
| 67 | 1.3.2.2.4 | Obtain Purchase Order Approval for Clover POS | milestone | 0d | 2019-07-19 14:02 | 2019-07-19 14:02 | 66 | 2.76d | 0d | Bruce Asberry; Project Sponsor |  |  |
| 68 | 1.3.2.2.5 | Submit Purchase Order to Clover |  | 0.25d | 2019-07-19 14:02 | 2019-07-19 16:02 | 67 | 2.76d | 0.76d | Tibletse Nigussie | 2h | 110 |
| 69 | 1.3.2.3 | **Custom Website** |  | 1.01d | 2019-07-19 14:02 | 2019-07-22 14:07 | 47SS | 2d | 0d |  | 22.08h | 1,204.4 |
| 70 | 1.3.2.3.1 | Identify Custom Website Requirements (hardware, software, domain registration, etc.) |  | 0.5d | 2019-07-19 14:02 | 2019-07-22 09:02 | 61 | 2d | 0d | Marco Antonio Rodriguez; Tibletse Nigussie; Nous (Web Developer) | 12h | 640 |
| 71 | 1.3.2.3.2 | Review and Finalize Custom Website Requirements |  | 0.25d | 2019-07-22 09:02 | 2019-07-22 11:02 | 70 | 2d | 0d | Bruce Asberry; Marco Antonio Rodriguez; Tibletse Nigussie; Nous (Web Developer) | 8h | 450 |
| 72 | 1.3.2.3.3 | Obtain Purchase Order Approval to Purchase Custom Website Infrastructure | milestone | 0d | 2019-07-22 11:02 | 2019-07-22 11:02 | 71 | 2d | 0d | Bruce Asberry |  |  |
| 73 | 1.3.2.3.4 | Submit Purchase Order to Support Cloud Infrastructure |  | 0.13d | 2019-07-22 11:02 | 2019-07-22 13:04 | 72 | 2d | 0d | Tibletse Nigussie | 1.04h | 57.2 |
| 74 | 1.3.2.3.5 | Submit Purchase Order to Domain Provider |  | 0.13d | 2019-07-22 13:04 | 2019-07-22 14:07 | 72, 73 | 2d | 0d | Tibletse Nigussie | 1.04h | 57.2 |
| 75 | 1.3.3 | **Vendor Agreements** |  | 1d | 2019-07-22 14:07 | 2019-07-23 14:07 | 55, 57, 63, 69, 56 | 2d |  |  | 16h | 520 |
| 76 | 1.3.3.1 | Obtain Service Agreement with ISP (FIOS) | milestone | 0d | 2019-07-22 14:07 | 2019-07-22 14:07 | 55 | 2d | 0d | Verizon FIOS; Tibletse Nigussie |  |  |
| 77 | 1.3.3.2 | Obtain End-User Agreements from SysPro ERP | milestone | 0d | 2019-07-22 14:07 | 2019-07-22 14:07 | 62, 76 | 2d | 0d | SysPro ERP; Tibletse Nigussie |  |  |
| 78 | 1.3.3.3 | Obtain End-User Agreements from Clover POS | milestone | 0d | 2019-07-22 14:07 | 2019-07-22 14:07 | 68, 77 | 2d | 0d | Clover POS; Tibletse Nigussie |  |  |
| 79 | 1.3.3.4 | Obtain Cloud Infrastructure Agreement | milestone | 0d | 2019-07-22 14:07 | 2019-07-22 14:07 | 78 | 2d | 0d | Tibletse Nigussie |  |  |
| 80 | 1.3.3.5 | Obtain End-User Agreement with Domain Provider | milestone | 0d | 2019-07-22 14:07 | 2019-07-22 14:07 | 78, 74, 79 | 2d | 0d | Tibletse Nigussie |  |  |
| 81 | 1.3.3.6 | Review End-User and Service Agreements with Project Sponsor |  | 1d | 2019-07-22 14:07 | 2019-07-23 14:07 | 78, 77, 76, 80 | 2d | 0d | Bruce Asberry; Project Sponsor | 16h | 520 |
| 82 | 1.3.3.7 | Obtain End-User and Service Agreements Sign-Offs | milestone | 0d | 2019-07-23 14:07 | 2019-07-23 14:07 | 81 | 2d |  | Project Sponsor |  |  |

| ID | WBS | Task | Type | Duration | Start | Finish | Predecessors | Total slack | Free slack | Resources | Work | Cost |
| --- | --- | --- | --- | --- | --- | --- | --- | --- | --- | --- | --- | --- |
| 83 | 1.3.4 | **Network Infrastructure** |  | 3d | 2019-07-22 14:07 | 2019-07-25 14:07 | 63 | 0d |  |  | 60h | 8,631 |
| 84 | 1.3.4.1 | Identify Network Requirements including routers, firewall, etc. |  | 2d | 2019-07-22 14:07 | 2019-07-24 14:07 | 56, 47 | 0d |  | Marco Antonio Rodriguez; Tibletse Nigussie; Bruce Asberry | 48h | 2,800 |
| 85 | 1.3.4.2 | Review Network Requirements with Project Sponsor |  | 0.5d | 2019-07-24 14:07 | 2019-07-25 09:07 | 84 | 0d |  | Tibletse Nigussie; Bruce Asberry; Dell Vostro 15” Small Business Laptops [200%]; Cat 6A Cable; Sophos XG 135 Wireless Next Generation Firewall | 8h | 5,611 |
| 86 | 1.3.4.3 | Obtain Project Sponsor Approval for Network Infrastructure | milestone | 0d | 2019-07-25 09:07 | 2019-07-25 09:07 | 85 | 0d |  | Bruce Asberry; Project Sponsor |  |  |
| 87 | 1.3.4.4 | Initiate and Submit Purchase Order for Network Infrastructure |  | 0.5d | 2019-07-25 09:07 | 2019-07-25 14:07 | 86 | 0d |  | Tibletse Nigussie | 4h | 220 |
| 88 | 1.3.5 | **Obtain Hardware** |  | 0d | 2019-07-25 14:07 | 2019-07-25 14:07 | 83, 82, 75 | 0d |  |  |  |  |
| 89 | 1.3.5.1 | Receive SysPro ERP components | milestone | 0d | 2019-07-25 14:07 | 2019-07-25 14:07 | 82, 62 | 0d |  | Marco Antonio Rodriguez |  |  |
| 90 | 1.3.5.2 | Receive Clover POS components | milestone | 0d | 2019-07-25 14:07 | 2019-07-25 14:07 | 89, 82 | 0d |  | Marco Antonio Rodriguez |  |  |
| 91 | 1.3.5.3 | Receive Hardware to Support Website Installation | milestone | 0d | 2019-07-25 14:07 | 2019-07-25 14:07 | 89, 90, 82 | 0d |  | Marco Antonio Rodriguez |  |  |
| 92 | 1.3.5.4 | Receive Network Infrastructure Hardware | milestone | 0d | 2019-07-25 14:07 | 2019-07-25 14:07 | 91, 87 | 0d |  | Marco Antonio Rodriguez |  |  |
| 93 | 1.4 | **Project Development Phase** |  | 52d | 2019-07-25 14:07 | 2019-10-08 14:07 | 47, 55SS, 46 | 17d | 0d |  | 808h | 40,920 |
| 94 | 1.4.1 | **Development Iteration 1** |  | 14d | 2019-07-25 14:07 | 2019-08-14 14:07 | 55, 47 | 17d | 0d |  | 228h | 11,560 |
| 95 | 1.4.1.1 | Finalize Work Package 1 |  | 1d | 2019-07-25 14:07 | 2019-07-26 14:07 | 55 | 17d | 0d | Bruce Asberry; Marco Antonio Rodriguez; Micheal Mays | 24h | 1,360 |
| 96 | 1.4.1.2 | Develop, Test and Debug Work Package 1 |  | 9.5d | 2019-07-26 14:07 | 2019-08-09 09:07 | 95 | 17d | 0d | Micheal Mays; Nous (Web Developer) | 152h | 7,600 |
| 97 | 1.4.1.3 | Initial demo of Custom Website |  | 0.5d | 2019-08-09 09:07 | 2019-08-09 14:07 | 96 | 17d | 0d | Micheal Mays | 4h | 200 |
| 98 | 1.4.1.4 | Additional Development based on feedback on Work Package 1 |  | 3d | 2019-08-09 14:07 | 2019-08-14 14:07 | 97 | 17d | 0d | Micheal Mays; Nous (Web Developer) | 48h | 2,400 |
| 99 | 1.4.2 | **Development Iteration 2** |  | 13d | 2019-08-14 14:07 | 2019-09-03 14:07 | 94, 98 | 17d | 0d |  | 212h | 10,680 |
| 100 | 1.4.2.1 | Finalize Work Package 2 |  | 0.5d | 2019-08-14 14:07 | 2019-08-15 09:07 | 95 | 17d | 0d | Bruce Asberry; Marco Antonio Rodriguez; Micheal Mays | 12h | 680 |
| 101 | 1.4.2.2 | Develop, Test and Debug Work Package 2 |  | 10.5d | 2019-08-15 09:07 | 2019-08-29 14:07 | 100 | 17d | 0d | Micheal Mays; Nous (Web Developer) | 168h | 8,400 |
| 102 | 1.4.2.3 | Additional Development based on feedback on Work Package 2 |  | 2d | 2019-08-29 14:07 | 2019-09-03 14:07 | 101 | 17d | 0d | Micheal Mays; Nous (Web Developer) | 32h | 1,600 |
| 103 | 1.4.3 | **Development Iteration 3** |  | 10d | 2019-09-03 14:07 | 2019-09-17 14:07 | 99, 102 | 17d | 0d |  | 164h | 8,280 |
| 104 | 1.4.3.1 | Finalize Work Package 3 |  | 0.5d | 2019-09-03 14:07 | 2019-09-04 09:07 | 100 | 17d | 0d | Bruce Asberry; Marco Antonio Rodriguez; Micheal Mays | 12h | 680 |
| 105 | 1.4.3.2 | Develop, Test and Debug Work Package 3 |  | 9d | 2019-09-04 09:07 | 2019-09-17 09:07 | 104 | 17d | 0d | Micheal Mays; Nous (Web Developer) | 144h | 7,200 |
| 106 | 1.4.3.3 | Additional Development based on feedback on Work Package 3 |  | 0.5d | 2019-09-17 09:07 | 2019-09-17 14:07 | 105 | 17d | 0d | Micheal Mays; Nous (Web Developer) | 8h | 400 |

| ID | WBS | Task | Duration | Start | Finish | Predecessors | Total slack | Free slack | Resources | Work | Cost |
| --- | --- | --- | --- | --- | --- | --- | --- | --- | --- | --- | --- |
| 107 | 1.4.4 | **Development Iteration 4** | 10d | 2019-09-17 14:07 | 2019-10-01 14:07 | 103, 106 | 17d | 0d |  | 164h | 8,280 |
| 108 | 1.4.4.1 | Finalize Work Package 4 | 0.5d | 2019-09-17 14:07 | 2019-09-18 09:07 | 104 | 17d | 0d | Bruce Asberry; Marco Antonio Rodriguez; Micheal Mays | 12h | 680 |
| 109 | 1.4.4.2 | Develop, Test and Debug Work Package 4 | 9d | 2019-09-18 09:07 | 2019-10-01 09:07 | 108 | 17d | 0d | Micheal Mays; Nous (Web Developer) | 144h | 7,200 |
| 110 | 1.4.4.3 | Additional Development based on feedback on Work Package 4 | 0.5d | 2019-10-01 09:07 | 2019-10-01 14:07 | 109 | 17d |  | Micheal Mays; Nous (Web Developer) | 8h | 400 |
| 111 | 1.4.5 | **End-User Documentation** | 5d | 2019-10-01 14:07 | 2019-10-08 14:07 | 47, 94, 99, 103, 107 | 17d | 13d |  | 40h | 2,120 |
| 112 | 1.4.5.1 | Draft End-User Documentation based on Requirements | 3d | 2019-10-01 14:07 | 2019-10-04 14:07 | 47 | 17d | 0d | Mark Fowler | 24h | 1,080 |
| 113 | 1.4.5.2 | Review and Finalize End-User Documentation | 2d | 2019-10-04 14:07 | 2019-10-08 14:07 | 112 | 17d |  | Bruce Asberry | 16h | 1,040 |
| 114 | 1.5 | **Project Implementation Phase** | 70d | 2019-07-25 14:07 | 2019-11-04 14:07 | 93SS | 0d |  |  | 340h | 19,859.88 |
| 115 | 1.5.1 | **Prerequisites** | 5d | 2019-07-25 14:07 | 2019-08-01 14:07 | 88 | 0d |  |  | 56h | 4,399.88 |
| 116 | 1.5.1.1 | Installation of FIOS Business | 1d | 2019-07-25 14:07 | 2019-07-26 14:07 | 88 | 2d |  | Verizon FIOS [0.1%] |  | 1,319.88 |
| 117 | 1.5.1.2 | Installation and setup of Network Infrastructure (routers, firewall, cabling, etc.) | 3d | 2019-07-25 14:07 | 2019-07-30 14:07 | 116FF, 92 | 0d |  | Marco Antonio Rodriguez | 24h | 1,320 |
| 118 | 1.5.1.3 | Installation and setup of All-In-One Printer, Laptops, Security Software | 2d | 2019-07-26 14:07 | 2019-07-30 14:07 | 117FF | 0d |  | Marco Antonio Rodriguez | 16h | 880 |
| 119 | 1.5.1.4 | Conduct smoke tests of infrastructure (e.g. internet, hot spots, etc.) | 2d | 2019-07-30 14:07 | 2019-08-01 14:07 | 117, 118 | 0d |  | Tibletse Nigussie | 16h | 880 |
| 120 | 1.5.2 | **Installation** | 51d | 2019-07-30 14:07 | 2019-10-10 14:07 | 115SS, 119SS | 0d |  |  | 112h | 6,080 |
| 121 | 1.5.2.1 | Install and configure SysPro ERP system | 2d | 2019-07-30 14:07 | 2019-08-01 14:07 | 117FF | 45d | 0d | SysPro ERP [0.1%]; Tibletse Nigussie | 16h | 880 |
| 122 | 1.5.2.2 | Install and configure Clover POS | 2d | 2019-07-30 14:07 | 2019-08-01 14:07 | 117FF | 49d |  | Clover POS [0.1%]; Tibletse Nigussie | 16h | 880 |
| 123 | 1.5.2.3 | Transfer legacy data into new SysPro ERP system | 2d | 2019-08-01 14:07 | 2019-08-05 14:07 | 121 | 45d |  | Marco Antonio Rodriguez; Tibletse Nigussie | 32h | 1,760 |
| 124 | 1.5.2.4 | Install and configure custom website | 2d | 2019-10-08 14:07 | 2019-10-10 14:07 | 93, 123 | 0d |  | Marco Antonio Rodriguez; Tibletse Nigussie; Micheal Mays | 48h | 2,560 |
| 125 | 1.5.3 | **Testing** | 11d | 2019-10-10 14:07 | 2019-10-28 14:07 | 120, 122, 124, 121 | 0d |  |  | 152h | 8,280 |
| 126 | 1.5.3.1 | Smoke test of overall systems | 2d | 2019-10-10 14:07 | 2019-10-15 14:07 | 120, 123 | 0d |  | Tibletse Nigussie; Marco Antonio Rodriguez | 32h | 1,760 |
| 127 | 1.5.3.2 | Reinstall and follow-up testing of overall systems | 1.5d | 2019-10-15 14:07 | 2019-10-17 09:07 | 126 | 0d |  | Tibletse Nigussie; Marco Antonio Rodriguez | 24h | 1,320 |
| 128 | 1.5.3.3 | Schedule System Test and Validation | 0.25d | 2019-10-15 14:07 | 2019-10-15 16:07 | 127SS | 1.5d | 0d | Tibletse Nigussie | 2h | 110 |
| 129 | 1.5.3.4 | Conduct System Test and Validation | 3d | 2019-10-15 16:07 | 2019-10-18 16:07 | 128 | 1.5d | 0d | Tibletse Nigussie; Marco Antonio Rodriguez | 48h | 2,640 |
| 130 | 1.5.3.5 | Schedule User Acceptance Testing | 0.25d | 2019-10-18 16:07 | 2019-10-21 09:07 | 129 | 1.5d | 0d | Tibletse Nigussie | 2h | 110 |
| 131 | 1.5.3.6 | Conduct User Acceptance Testing | 2.5d | 2019-10-21 09:07 | 2019-10-23 14:07 | 130, 129 | 1.5d | 0d | Tibletse Nigussie | 20h | 1,100 |
| 132 | 1.5.3.7 | Analyze Defects and Correct | 2d | 2019-10-23 14:07 | 2019-10-25 14:07 | 131 | 1.5d | 0d | Micheal Mays | 16h | 800 |
| 133 | 1.5.3.8 | Conduct Final User Acceptance Testing | 1d | 2019-10-25 14:07 | 2019-10-28 14:07 | 132 | 1.5d |  | Tibletse Nigussie | 8h | 440 |

| ID | WBS | Task | Type | Duration | Start | Finish | Predecessors | Total slack | Resources | Work | Cost |
| --- | --- | --- | --- | --- | --- | --- | --- | --- | --- | --- | --- |
| 134 | 1.5.4 | **Training** |  | 4d | 2019-10-28 14:07 | 2019-11-01 14:07 | 125, 111 | 0d |  | 12h | 580 |
| 135 | 1.5.4.1 | Provide User Training in use of SysPro ERP. |  | 1.5d | 2019-10-28 14:07 | 2019-10-30 09:07 |  | 0d | SysPro ERP [0.1%] |  |  |
| 136 | 1.5.4.2 | Provide User Training in use of Clover POS. |  | 1d | 2019-10-30 09:07 | 2019-10-31 09:07 | 133, 135 | 0d | Clover POS [0.1%] |  |  |
| 137 | 1.5.4.3 | Provide User Training in use of custom website. |  | 1d | 2019-10-31 09:07 | 2019-11-01 09:07 | 136 | 0d | Mark Fowler | 8h | 360 |
| 138 | 1.5.4.4 | Deliver SysPro ERP, Clover POS, Website user manuals |  | 0.5d | 2019-11-01 09:07 | 2019-11-01 14:07 | 136, 137 | 0d | Clover POS [0.1%]; Marco Antonio Rodriguez; SysPro ERP [0.1%] | 4h | 220 |
| 139 | 1.5.5 | **Support and Maintenance** |  | 1d | 2019-11-01 14:07 | 2019-11-04 14:07 | 134 | 0d |  | 8h | 520 |
| 140 | 1.5.5.1 | Hand-off of Project Deliverables |  | 0.5d | 2019-11-01 14:07 | 2019-11-04 09:07 | 113, 138 | 0d | Bruce Asberry | 4h | 260 |
| 141 | 1.5.5.2 | Final Acceptance Status Meeting |  | 0.5d | 2019-11-04 09:07 | 2019-11-04 14:07 | 140 | 0d | Bruce Asberry | 4h | 260 |
| 142 | 1.5.5.3 | Obtain Project Sponsor Acceptance | milestone | 0d | 2019-11-04 14:07 | 2019-11-04 14:07 | 140, 141 | 0d | Project Sponsor |  |  |
| 143 | 1.5.6 | Go-Live | milestone | 0d | 2019-11-04 14:07 | 2019-11-04 14:07 | 142, 139 | 0d | Bruce Asberry; Project Sponsor |  |  |
