# C:\Users\AGRO\Downloads\Desktop\pom project\projectmanagement\yourlastname-POM 3

Schedule from MS Project, 2021-01-04 to 2021-08-09, costs in $, A marks actual dates.

## Calendars

- Standard: Mon-Fri 08:00-12:00, 13:00-17:00; Sat-Sun off.

## Resources

| Resource | Rate |
| --- | --- |
| MRKT | 80 |
| R&D | 80 |
| PURCH | 60 |
| ENG | 100 |
| PROD | 60 |
| QUAL | 80 |
| DESIGN | 60 |
| LEGAL | 120 |

## Schedule

| ID | WBS | Task | Duration | Start | Finish | Predecessors | Complete | Remaining | Baseline start | Baseline finish | Baseline duration | Total slack | Free slack | Constraint | Resources | Work | Actual work | Cost | Baseline cost | Actual cost |
| --- | --- | --- | --- | --- | --- | --- | --- | --- | --- | --- | --- | --- | --- | --- | --- | --- | --- | --- | --- | --- |
| 1 | 1 | **POM+Project** | 156d | 2021-01-04 A | 2021-08-09 |  | 26% | 114.84d | 2021-01-04 | 2021-07-09 | 135d | 0d |  |  |  | 19784h | 6344h | 1,502,720 | 1,497,600 | 470,720 |
| 2 | 1.1 | **R&D product development** | 71.67d | 2021-01-04 A | 2021-04-13 |  | 70% | 21.67d | 2021-01-04 | 2021-04-02 | 65d | 14.33d |  |  |  | 1024h | 824h | 78,720 | 73,600 | 65,920 |
| 3 | 1.1.1 | Need survey | 22d | 2021-01-04 A | 2021-02-02 A |  | 100% |  | 2021-01-04 | 2021-01-29 | 20d |  |  | start no earlier than 2021-01-04 | MRKT | 176h | 176h | 14,080 | 12,800 | 14,080 |
| 4 | 1.1.2 | Set product specs | 18d | 2021-02-03 A | 2021-02-26 A | 3 | 100% |  | 2021-02-01 | 2021-02-19 | 15d |  |  |  | R&D [400%]; MRKT [200%] | 408h | 408h | 32,640 | 28,800 | 32,640 |
| 5 | 1.1.3 | Shelf life report | 10d | 2021-02-27 A | 2021-03-12 A | 4 | 100% |  | 2021-02-22 | 2021-03-05 | 10d |  |  |  | R&D [300%] | 240h | 240h | 19,200 | 19,200 | 19,200 |
| 6 | 1.1.4 | Nutrition report | 1.67d | 2021-03-15 | 2021-03-16 | 4 |  |  | 2021-03-04 | 2021-03-05 | 1.67d | 14.33d | 0d |  | R&D [300%] | 40h |  | 3,200 | 3,200 |  |
| 7 | 1.1.5 | Select fruit suppliers | 20d | 2021-03-16 | 2021-04-13 | 5, 6 |  |  | 2021-03-08 | 2021-04-02 | 20d | 14.33d | 10d |  | PURCH | 160h |  | 9,600 | 9,600 |  |
| 8 | 1.2 | **Initial Praduction** | 85d | 2021-03-23 A | 2021-07-19 |  | 27% | 62d | 2021-02-22 | 2021-06-18 | 85d | 0d |  |  |  | 11640h | 5520h | 861,600 | 861,600 | 404,800 |
| 9 | 1.2.1 | Equipmant rabab | 30d | 2021-03-23 A | 2021-05-03 | 4 | 77% | 7d | 2021-02-22 | 2021-04-02 | 30d | 0d |  |  | ENG [1000%]; PROD [2000%] | 7200h | 5520h | 528,000 | 528,000 | 404,800 |
| 10 | 1.2.2 | Production trials | 15d | 2021-05-04 | 2021-05-24 | 7, 9 |  |  | 2021-04-05 | 2021-04-23 | 15d | 0d |  |  | PROD [1500%]; PURCH; ENG [1000%] | 2520h |  | 199,200 | 199,200 |  |
| 11 | 1.2.3 | Quality trials | 20d | 2021-05-25 | 2021-06-21 | 10 |  |  | 2021-04-26 | 2021-05-21 | 20d | 0d |  |  | QUAL [300%]; PROD [500%] | 1280h |  | 86,400 | 86,400 |  |
| 12 | 1.2.4 | Quality metrics | 5d | 2021-06-22 | 2021-06-28 | 11 |  |  | 2021-05-24 | 2021-05-28 | 5d | 0d |  |  | QUAL [300%]; PROD | 160h |  | 12,000 | 12,000 |  |
| 13 | 1.2.5 | Quality training | 15d | 2021-06-29 | 2021-07-19 | 12 |  |  | 2021-05-31 | 2021-06-18 | 15d | 0d |  |  | QUAL [300%]; PROD | 480h |  | 36,000 | 36,000 |  |
| 14 | 1.3 | **Distribution** | 70d | 2021-03-16 | 2021-06-22 |  |  |  | 2021-03-08 | 2021-06-11 | 70d | 19.33d |  |  |  | 2680h |  | 207,200 | 207,200 |  |
| 15 | 1.3.1 | Market testing | 30d | 2021-03-16 | 2021-04-27 | 5, 6 |  |  | 2021-03-08 | 2021-04-16 | 30d | 19.33d | 0d |  | MRKT [500%] | 1200h |  | 96,000 | 96,000 |  |
| 16 | 1.3.2 | Package design | 30d | 2021-04-27 | 2021-06-22 | 15 |  |  | 2021-04-19 | 2021-06-11 | 30d | 19.33d |  |  | DESIGN [300%]; MRKT | 480h |  | 31,200 | 31,200 |  |
| 17 | 1.3.3 | Select distributors | 25d | 2021-04-27 | 2021-06-01 | 7, 15 |  |  | 2021-04-19 | 2021-05-21 | 25d | 34.33d |  |  | MRKT [500%] | 1000h |  | 80,000 | 80,000 |  |
| 18 | 1.4 | **Legal** | 19.67d | 2021-04-27 | 2021-05-25 |  |  |  | 2021-04-19 | 2021-05-14 | 20d | 19.33d |  |  |  | 720h |  | 86,400 | 86,400 |  |
| 19 | 1.4.1 | Complete FDA certification | 15d | 2021-04-27 | 2021-05-18 | 7, 15 |  |  | 2021-04-19 | 2021-05-07 | 15d | 19.33d |  |  | LEGAL [500%] | 600h |  | 72,000 | 72,000 |  |
| 20 | 1.4.2 | Register trademark | 5d | 2021-04-27 | 2021-05-25 | 7, 15 |  |  | 2021-05-10 | 2021-05-14 | 5d | 24.67d |  |  | LEGAL [300%] | 120h |  | 14,400 | 14,400 |  |
| 21 | 1.5 | Prepare product lauch | 15d | 2021-07-20 | 2021-08-09 | 13, 16, 17, 19FS+25d, 20FS+15d |  |  | 2021-06-21 | 2021-07-09 | 15d | 0d |  |  | QUAL [300%]; PURCH [200%]; PROD [1500%]; MRKT [500%]; ENG [500%]; R&D | 3720h |  | 268,800 | 268,800 |  |
