# C:\Users\AGRO\Downloads\Desktop\pom project\projectmanagement\yourlastname-POM 3

Schedule from MS Project, 2020-07-02 to 2021-07-26, costs in $, A marks actual dates.

## Calendars

- Standard: Mon-Fri 08:00-12:00, 13:00-17:00; Sat-Sun off.

## Resources

| Resource | Rate |
| --- | --- |
| MRKT | 80 |
| R&D | 80 |
| PURCH | 60 |
| ENG | 100 |
| PROD | 60 |
| QUAL | 80 |
| DESIGN | 60 |
| LEGAL | 120 |

## Schedule

| ID | WBS | Task | Type | Duration | Start | Finish | Predecessors | Complete | Remaining | Baseline start | Baseline finish | Baseline duration | Total slack | Free slack | Constraint | Resources | Work | Actual work | Cost | Baseline cost | Actual cost |
| --- | --- | --- | --- | --- | --- | --- | --- | --- | --- | --- | --- | --- | --- | --- | --- | --- | --- | --- | --- | --- | --- |
| 1 | 1 | **POM+Project** |  | 277d | 2020-07-02 A | 2021-07-26 |  | 72% | 76.94d | 2021-01-04 | 2021-07-09 | 135d | 0d |  |  |  | 19136h | 13656h | 1,453,120 | 1,497,600 | 1,041,920 |
| 2 | 1.1 | **R&D product development** |  | 187d | 2020-07-02 A | 2021-03-22 A |  | 100% |  | 2021-01-04 | 2021-04-02 | 65d |  |  |  |  | 968h | 968h | 77,440 | 73,600 | 77,440 |
| 3 | 1.1.1 | Need survey |  | 22d | 2021-01-04 A | 2021-02-02 A |  | 100% |  | 2021-01-04 | 2021-01-29 | 20d |  |  | start no earlier than 2021-01-04 | MRKT | 176h | 176h | 14,080 | 12,800 | 14,080 |
| 4 | 1.1.2 | Set product specs |  | 18d | 2021-02-03 A | 2021-02-26 A | 3 | 100% |  | 2021-02-01 | 2021-02-19 | 15d |  |  |  | R&D [400%]; MRKT [200%] | 408h | 408h | 32,640 | 28,800 | 32,640 |
| 5 | 1.1.3 | Shelf life report |  | 10d | 2021-02-27 A | 2021-03-12 A | 4 | 100% |  | 2021-02-22 | 2021-03-05 | 10d |  |  |  | R&D [300%] | 240h | 240h | 19,200 | 19,200 | 19,200 |
| 6 | 1.1.4 | Nutrition report |  | 6d | 2021-03-15 A | 2021-03-22 A | 4 | 100% |  | 2021-03-04 | 2021-03-05 | 1.67d |  |  |  | R&D [300%] | 144h | 144h | 11,520 | 3,200 | 11,520 |
| 7 | 1.1.5 | Select fruit suppliers | milestone | 0d | 2020-07-02 A | 2020-07-02 A | 5, 6 | 100% |  | 2021-03-08 | 2021-04-02 | 20d |  |  |  | PURCH |  |  |  | 9,600 |  |
| 8 | 1.2 | **Initial Praduction** |  | 87d | 2021-03-01 A | 2021-06-30 |  | 75% | 21.48d | 2021-02-22 | 2021-06-18 | 85d | 3d |  |  |  | 11336h | 10696h | 836,000 | 861,600 | 788,000 |
| 9 | 1.2.1 | Equipmant rabab |  | 30d | 2021-03-01 A | 2021-04-12 A | 4 | 100% |  | 2021-02-22 | 2021-04-02 | 30d |  |  |  | ENG [1000%]; PROD [2000%] | 7200h | 7200h | 528,000 | 528,000 | 528,000 |
| 10 | 1.2.2 | Production trials |  | 13d | 2021-04-19 A | 2021-05-05 A | 7, 9 | 100% |  | 2021-04-05 | 2021-04-23 | 15d |  |  |  | PROD [1500%]; PURCH; ENG [1000%] | 2344h | 2344h | 182,240 | 199,200 | 182,240 |
| 11 | 1.2.3 | Quality trials |  | 18d | 2021-05-10 A | 2021-06-02 A | 10 | 100% |  | 2021-04-26 | 2021-05-21 | 20d |  |  |  | QUAL [300%]; PROD [500%] | 1152h | 1152h | 77,760 | 86,400 | 77,760 |
| 12 | 1.2.4 | Quality metrics |  | 5d | 2021-06-03 | 2021-06-09 | 11 |  |  | 2021-05-24 | 2021-05-28 | 5d | 3d | 0d |  | QUAL [300%]; PROD | 160h |  | 12,000 | 12,000 |  |
| 13 | 1.2.5 | Quality training |  | 15d | 2021-06-10 | 2021-06-30 | 12 |  |  | 2021-05-31 | 2021-06-18 | 15d | 3d |  |  | QUAL [300%]; PROD | 480h |  | 36,000 | 36,000 |  |
| 14 | 1.3 | **Distribution** |  | 64d | 2021-04-05 A | 2021-07-01 |  | 60% | 25.4d | 2021-03-08 | 2021-06-11 | 70d | 2d |  |  |  | 2432h | 1432h | 189,280 | 207,200 | 109,280 |
| 15 | 1.3.1 | Market testing |  | 27d | 2021-04-05 A | 2021-05-11 A | 5, 6 | 100% |  | 2021-03-08 | 2021-04-16 | 30d |  |  |  | MRKT [500%] | 1080h | 1080h | 86,400 | 96,000 | 86,400 |
| 16 | 1.3.2 | Package design |  | 11d | 2021-05-11 A | 2021-05-26 A | 15 | 100% |  | 2021-04-19 | 2021-06-11 | 30d |  |  |  | DESIGN [300%]; MRKT | 352h | 352h | 22,880 | 31,200 | 22,880 |
| 17 | 1.3.3 | Select distributors |  | 25d | 2021-05-28 A | 2021-07-01 | 7, 15 |  | 25d | 2021-04-19 | 2021-05-21 | 25d | 2d |  |  | MRKT [500%] | 1000h |  | 80,000 | 80,000 |  |
| 18 | 1.4 | **Legal** |  | 24d | 2021-05-05 A | 2021-06-07 |  | 74% | 6.32d | 2021-04-19 | 2021-05-14 | 20d | 5d |  |  |  | 680h | 560h | 81,600 | 86,400 | 67,200 |
| 19 | 1.4.1 | Complete FDA certification |  | 14d | 2021-05-05 A | 2021-05-31 A | 7, 15 | 100% |  | 2021-04-19 | 2021-05-07 | 15d |  |  |  | LEGAL [500%] | 560h | 560h | 67,200 | 72,000 | 67,200 |
| 20 | 1.4.2 | Register trademark |  | 5d | 2021-06-01 | 2021-06-07 | 7, 15 |  |  | 2021-05-10 | 2021-05-14 | 5d | 5d |  |  | LEGAL [300%] | 120h |  | 14,400 | 14,400 |  |
| 21 | 1.5 | Prepare product lauch |  | 15d | 2021-07-06 | 2021-07-26 | 13, 16, 17, 19FS+25d, 20FS+15d |  |  | 2021-06-21 | 2021-07-09 | 15d | 0d |  |  | QUAL [300%]; PURCH [200%]; PROD [1500%]; MRKT [500%]; ENG [500%]; R&D | 3720h |  | 268,800 | 268,800 |  |
